# Diploma - vnos podatkov

Schedule from MS Project, 2006-02-20 to 2006-11-25, status date 2006-06-30, 10 hours a day, costs in SIT, A marks actual dates.
Jerele Co.

## Calendars

- Standard: Mon-Fri 07:00-17:00; Sat 07:00-13:00; Sun off. Exceptions (off unless hours are given): 2006-02-20 to 2006-02-24 07:00-16:00, 2006-02-25 to 2006-02-26, 2006-02-27 to 2006-03-03 07:00-16:00, 2006-03-04, 2006-03-06 to 2006-03-10 07:00-16:00, 2006-03-11, 2006-04-03 07:00-16:00, 2006-04-11 07:00-15:00, 2006-04-12 to 2006-04-13 07:00-18:00, 2006-04-14 07:00-14:00, 2006-04-27 07:00-10:00, 2006-05-24 07:00-12:00, 2006-05-29 to 2006-05-30, 2006-06-11 07:00-13:00, 2006-08-15, 2006-10-31 to 2006-11-01.

## Resources

| Resource | Unit |
| --- | --- |
| PROFILI | kpl |
| BETON MB 30 | m3 |
| BETON MB 40 | m3 |
| MIKROARMIRANI BETON MB 30 | m3 |
| OPAŽ s podporami | m2 |
| HIDROIZOLACIJA | m2 |
| POLISTIREN | m2 |
| TAMPON | m3 |
| ZEMLJINA | m3 |
| ARMATURA | kg |
| STEKLENA MREŽICA | m2 |
| MALTA V PCM 1:3:9 | m2 |
| OMET V PCM 1:2:6 | m2 |
| PE FOLIJA | m2 |
| NAKLONSKI BETON | m2 |
| KOMBI PLOŠČE 12,5cm | m2 |
| KOMBI PLOŠČE 5cm | m2 |
| DIMNIK | m' |
| ODRI do višine 4,00m | m2 |
| ODRI do višine 7,00m | m2 |
| ODRI do višine 10,00m | m2 |
| PVC cevi za preboje ø 250 | kom |
| BC ø 60 cm | kom |
| BC ø 80cm | kom |
| PVC KANALIZACIJSKA CEV ø 150 | m' |
| PVC KANALIZACIJSKA CEV ø 200 | m' |
| PVC KANALIZACIJSKA CEV ø 250 | m' |
| PVC ø 80 | m' |
| DRENAŽNA CEV ø 160 | m' |
| SIFON | m' |
| LTŽ ø 100 | m' |
| LTŽ ø 125 | m' |
| KANALETE | m' |
| SILIKATNI OMET | m2 |
| BAGER |  |
| KAMION |  |
| ČRPALKA ZA VODO |  |
| HRUŠKA |  |
| ŽERJAV |  |
| BOBCAT |  |
| VALJAR |  |
| KOMATSU |  |
| ČRPALKA ZA BETON |  |
| VIBRACIJSKA PLOŠČA |  |
| PODLOŽNI BETON | m3 |
| SIPOREX 20cm | m2 |
| SIPOREX 10cm | m2 |
| OMB 20cm | m3 |
| DRENAŽNI NASIP | m3 |
| DELAVEC |  |
| FILC | m' |
| Specialist za meritve in oprema |  |
| GEOMEHANIK |  |
| VIBRATOR |  |
| ARMATURNE MREŽE | kg |
| HIDROZAN | m2 |
| LEPILNA MALTA | m2 |
| MIKROARMIRANI CEMENTNI ESTRIH | m2 |
| ZAKLJUČNI SLOJ FASADE | m2 |
| ELEKTRO MATERIAL |  |
| PVC cevi za preboje ø 150 | kom |
| PVC cevi za preboje ø 300 | kom |

## Schedule

| ID | WBS | Task | Duration | Start | Finish | Predecessors | Complete | Remaining | Baseline start | Baseline finish | Baseline duration | Total slack | Resources | Work | Actual work | Cost | Actual cost |
| --- | --- | --- | --- | --- | --- | --- | --- | --- | --- | --- | --- | --- | --- | --- | --- | --- | --- |
| 1 | 1 | **Poslovno stanovanjski objekt z garažno hišo - S4** | 214.5d | 2006-02-20 A | 2006-11-25 |  | 54% | 99.02d | 2006-02-20 | 2006-11-15 | 206d | 0d |  | 45456h | 32485.5h | 655,175,027.11 | 187,999,863.71 |
| 2 | 1.1 | **Gradbena dela** | 214.5d | 2006-02-20 A | 2006-11-25 |  | 64% | 77.32d | 2006-02-20 | 2006-11-15 | 206d | 0d |  | 43603.2h | 32350.5h | 286,807,577.1 | 166,769,993.09 |
| 3 | 1.1.1 | **Pripravljalna dela** | 9d | 2006-02-20 A | 2006-03-03 A |  | 100% |  | 2006-02-20 | 2006-03-10 | 13d |  |  | 49h | 49h |  |  |
| 4 | 1.1.1.1 | Geodetske storitve; Zakoličba objekta, Višinsko niveliranje | 1d | 2006-02-20 A | 2006-02-21 A |  | 100% |  | 2006-02-20 | 2006-02-21 | 1d |  | PROFILI [1 kpl]; DELAVEC [200%] | 20h | 20h |  |  |
| 5 | 1.1.1.2 | Zavarovanje gradbišča, postavitev gradbenih profilov | 1d | 2006-02-21 A | 2006-02-22 A | 4 | 100% |  | 2006-02-21 | 2006-02-22 | 1d |  | PROFILI [1 kpl]; DELAVEC [200%] | 20h | 20h |  |  |
| 6 | 1.1.1.3 | Nadzor geomehanika | 0.9d | 2006-03-03 A | 2006-03-03 A | 8SS+8d | 100% |  | 2006-03-09 | 2006-03-10 | 1d |  | GEOMEHANIK | 9h | 9h |  |  |
| 7 | 1.1.2 | **Zemeljska dela** | 88.9d | 2006-02-22 A | 2006-06-20 A |  | 100% |  | 2006-02-22 | 2006-06-13 | 83d |  |  | 4396.85h | 4396.85h | 27,083,443 | 27,083,443 |
| 8 | 1.1.2.1 | Strojni široki izkop gradbene jame | 34d | 2006-02-24 A | 2006-04-12 A | 5, 24 | 100% |  | 2006-02-24 | 2006-04-12 | 34d |  | BAGER [180%]; KAMION [200%] | 662.5h | 662.5h | 7,433,000 | 7,433,000 |
| 9 | 1.1.2.2 | Strojni izkop za pasovne in točkovne temelje | 43.1d | 2006-03-13 A | 2006-05-05 A | 8SS+10d, 6 | 100% |  | 2006-03-13 | 2006-05-13 | 48.76d |  | BAGER [49.8%]; KAMION [149.3%]; ČRPALKA ZA VODO [1%] | 862h | 862h | 2,517,170 | 2,517,170 |
| 10 | 1.1.2.3 | Ročno planiranje dna izkopa pasovnih in točkovnih temeljev | 42.1d | 2006-03-14 A | 2006-05-05 A | 9SS+3d | 100% |  | 2006-03-16 | 2006-05-03 | 37d |  | DELAVEC [200%] | 842h | 842h | 343,808 | 343,808 |
| 11 | 1.1.2.4 | Ročno planiranje dna izkopa gradbene jame | 42.1d | 2006-03-14 A | 2006-05-05 A | 9SS+3d | 100% |  | 2006-03-16 | 2006-05-03 | 37d |  | DELAVEC [200%] | 842h | 842h | 458,390 | 458,390 |
| 12 | 1.1.2.5 | Zasip za pasovnimi in točkovnimi temelji s tamponom in nabijanjem | 40.1d | 2006-03-23 A | 2006-05-12 A | 31SS+5d | 100% |  | 2006-03-30 | 2006-05-19 | 39d |  | TAMPON [300 m3]; BAGER [2.4%]; KAMION [9.5%]; VIBRACIJSKA PLOŠČA [9.5%]; DELAVEC [23.7%] | 180.45h | 180.45h | 1,153,440 | 1,153,440 |
| 13 | 1.1.2.6 | **Izdelava utrjenega tamponskega sloja** | 76.4d | 2006-03-14 A | 2006-06-20 A |  | 100% |  | 2006-03-16 | 2006-06-13 | 68d |  |  | 68.45h | 68.45h | 3,008,120 | 3,008,120 |
| 14 | 1.1.2.6.1 | • pod temelji | 42.7d | 2006-03-14 A | 2006-05-06 A | 9SS+3d | 100% |  | 2006-03-16 | 2006-05-03 | 37d |  | TAMPON [900 m3]; KAMION [0.7%]; BAGER [0.3%]; DELAVEC [14%] | 64.05h | 64.05h | 2,935,900 | 2,935,900 |
| 15 | 1.1.2.6.2 | • pod talno ploščo dvigal - notranje dvigalo | 1d | 2006-05-02 A | 2006-05-02 A | 14SS+20d | 100% |  | 2006-04-11 | 2006-04-12 | 1d |  | TAMPON [8 m3]; KAMION [5%]; BAGER [2%]; VIBRACIJSKA PLOŠČA [10%]; DELAVEC [10%] | 2.7h | 2.7h | 36,110 | 36,110 |
| 16 | 1.1.2.6.3 | • pod talno ploščo dvigal - zunanje dvigalo | 1d | 2006-06-20 A | 2006-06-20 A | 19 | 100% |  | 2006-06-12 | 2006-06-13 | 1d |  | TAMPON [15 m3]; BAGER [1.3%]; KAMION [3.1%]; VIBRACIJSKA PLOŠČA [6.3%]; DELAVEC [6.3%] | 1.7h | 1.7h | 36,110 | 36,110 |
| 17 | 1.1.2.7 | **Izdelava utrjenega tamponskega sloja z gramozom** | 20.7d | 2006-04-18 A | 2006-05-13 A |  | 100% |  | 2006-04-18 | 2006-05-15 | 20d |  |  | 217.35h | 217.35h | 2,160,320 | 2,160,320 |
| 18 | 1.1.2.7.1 | • med temelji oz. pod talno ploščo | 20.7d | 2006-04-18 A | 2006-05-13 A | 31SS+20d | 100% |  | 2006-04-18 | 2006-05-15 | 20d |  | TAMPON [650 m3]; BAGER [1.7%]; KAMION [10.3%]; VIBRACIJSKA PLOŠČA [6.9%]; VALJAR [17.2%]; DELAVEC [68.9%] | 217.35h | 217.35h | 2,160,320 | 2,160,320 |
| 19 | 1.1.2.8 | Zasip gradbene jame ob objektu | 33.5d | 2006-04-03 A | 2006-05-15 A | 20SS+2d | 100% |  | 2006-04-10 | 2006-06-12 | 48d |  | ZEMLJINA [800 m3]; BAGER [9.1%]; VALJAR [18.2%]; KAMION [18.2%]; DELAVEC [4.5%] | 167.5h | 167.5h | 732,145 | 732,145 |
| 20 | 1.1.2.9 | Drenažni nasip okoli objekta | 41.6d | 2006-04-03 A | 2006-05-25 A | 237SS+1d | 100% |  | 2006-04-06 | 2006-05-27 | 39d |  | BOBCAT [36.7%]; DRENAŽNI NASIP [450 m3]; KAMION [18.3%]; FILC [150 m']; DELAVEC [50%]; ŽERJAV [5%] | 457.6h | 457.6h | 1,878,750 | 1,878,750 |
| 21 | 1.1.2.10 | Meritve zbitosti tamponskega planuma | 1d | 2006-03-29 A | 2006-03-29 A | 28SS-1d | 100% |  | 2006-03-16 | 2006-03-17 | 1d |  | Specialist za meritve in oprema | 10h | 10h | 90,000 | 90,000 |
| 22 | 1.1.2.11 | Meritve zbitosti tamponskega planuma | 1d | 2006-04-24 A | 2006-04-24 A | 40SS-1d | 100% |  | 2006-04-24 | 2006-04-25 | 1d |  | Specialist za meritve in oprema | 10h | 10h | 90,000 | 90,000 |
| 23 | 1.1.2.12 | Rušenje kamnitega opornega zidu | 1d | 2006-03-29 A | 2006-03-29 A | 25SS | 100% |  | 2006-03-30 | 2006-03-31 | 1d |  | BAGER [17.8%]; KAMION [17.8%]; DELAVEC [4.4%] | 4h | 4h | 87,840 | 87,840 |
| 24 | 1.1.2.13 | Odstranitev asfalta | 2d | 2006-02-22 A | 2006-02-24 A | 5 | 100% |  | 2006-02-22 | 2006-02-24 | 2d |  | BAGER; KAMION [200%] | 60h | 60h | 457,650 | 457,650 |
| 25 | 1.1.2.14 | Odstranitev kovinske ograje | 1d | 2006-03-29 A | 2006-03-30 A | 9SS+14d | 100% |  | 2006-03-30 | 2006-03-31 | 1d |  | DELAVEC [10%] | 1h | 1h | 45,450 | 45,450 |
| 26 | 1.1.2.15 | Odstranitev objekta TP | 1d | 2006-04-19 A | 2006-04-19 A | 9FS-22d | 100% |  | 2006-04-15 | 2006-04-17 | 1d |  | BAGER; KAMION [10%]; DELAVEC [10%] | 12h | 12h | 372,000 | 372,000 |

| ID | WBS | Task | Duration | Start | Finish | Predecessors | Complete | Remaining | Baseline start | Baseline finish | Baseline duration | Total slack | Free slack | Resources | Work | Actual work | Cost | Actual cost |
| --- | --- | --- | --- | --- | --- | --- | --- | --- | --- | --- | --- | --- | --- | --- | --- | --- | --- | --- |
| 27 | 1.1.3 | **Betonska in AB dela** | 146.7d | 2006-03-08 A | 2006-09-13 |  | 79% | 30.1d | 2006-03-17 | 2006-09-02 | 131d | 51d |  |  | 25873.1h | 20396.9h | 125,900,949.5 | 98,641,810.02 |
| 28 | 1.1.3.1 | Podložni beton | 46d | 2006-03-14 A | 2006-06-21 A | 10SS+1d | 100% |  | 2006-03-17 | 2006-05-16 | 46d |  |  | PODLOŽNI BETON [58.75 m3]; DELAVEC; BAGER [4.2%]; HRUŠKA [8.5%] | 253h | 253h | 1,139,562 | 1,139,562 |
| 29 | 1.1.3.2 | **Pasovni temelji** | 43.7d | 2006-03-17 A | 2006-05-11 A |  | 100% |  | 2006-03-21 | 2006-05-17 | 44d |  |  |  | 2624.4h | 2624.4h | 10,499,125 | 10,499,125 |
| 30 | 1.1.3.2.1 | • temeljna peta | 43d | 2006-03-17 A | 2006-05-11 A | 28SS+3d | 100% |  | 2006-03-21 | 2006-05-16 | 43d |  |  | BETON MB 30 [223.5 m3]; DELAVEC [248.2%]; VIBRATOR [33.1%]; HRUŠKA [18.8%] | 1290h | 1290h | 4,837,625 | 4,837,625 |
| 31 | 1.1.3.2.2 | • temeljna greda | 41.7d | 2006-03-20 A | 2006-05-11 A | 30SS+2d | 100% |  | 2006-03-23 | 2006-05-17 | 42d |  |  | BETON MB 30 [270.25 m3]; DELAVEC [257.1%]; VIBRATOR [42.9%]; HRUŠKA [20%] | 1334.4h | 1334.4h | 5,661,500 | 5,661,500 |
| 32 | 1.1.3.3 | Točkovni temelji | 42d | 2006-03-17 A | 2006-05-10 A | 30SS | 100% |  | 2006-03-21 | 2006-05-15 | 42d |  |  | BETON MB 30 [79.25 m3]; DELAVEC [86.6%]; VIBRATOR [8.7%]; HRUŠKA [4.8%] | 420h | 420h | 1,732,250 | 1,732,250 |
| 33 | 1.1.3.4 | **Pasovni temelji** | 1d | 2006-07-01 A | 2006-07-03 |  |  | 1d | 2006-05-25 | 2006-05-26 | 1d | 108d |  |  | 41h |  | 190,125 |  |
| 34 | 1.1.3.4.1 | • temelji za rampe v 1. nadstropje | 1d | 2006-07-01 A | 2006-07-03 | 14, 159 |  | 1d | 2006-05-25 | 2006-05-26 | 1d | 108d |  | BETON MB 30 [4 m3]; DELAVEC [195.1%]; VIBRATOR [4.9%]; HRUŠKA [5%] | 20.5h |  | 95,062.5 |  |
| 35 | 1.1.3.4.2 | • temelji za rampe v 2. nadstropje | 1d | 2006-07-01 A | 2006-07-03 | 14, 160 |  | 1d | 2006-05-25 | 2006-05-26 | 1d | 108d | 57d | BETON MB 30 [5 m3]; DELAVEC [195.1%]; VIBRATOR [4.9%]; HRUŠKA [5%] | 20.5h |  | 95,062.5 |  |
| 36 | 1.1.3.5 | **Oporni zid s temeljem, temelji rampe ter zunanjih stopnic** | 2d | 2006-07-01 A | 2006-07-04 |  |  | 2d | 2006-06-21 | 2006-06-23 | 2d | 107d |  |  | 41h |  | 64,061.5 |  |
| 37 | 1.1.3.5.1 | • pred vhodom v trgovino | 2d | 2006-07-01 A | 2006-07-04 | 162SS+7d |  | 2d | 2006-06-21 | 2006-06-23 | 2d | 107d | 56d | BETON MB 30 [3 m3]; DELAVEC [197%]; VIBRATOR [3%]; HRUŠKA [5%] | 41h |  | 64,061.5 |  |
| 38 | 1.1.3.6 | **Zunanje stopnice** | 1d | 2006-07-01 A | 2006-07-03 |  |  | 1d | 2006-06-15 | 2006-06-16 | 1d | 87d |  |  | 20.2h |  | 12,399 |  |
| 39 | 1.1.3.6.1 | • pred vhodom v trgovino | 1d | 2006-07-01 A | 2006-07-03 | 164SS+3d |  | 1d | 2006-06-15 | 2006-06-16 | 1d | 87d | 0d | BETON MB 30 [1 m3]; DELAVEC [198%]; VIBRATOR [2%]; HRUŠKA [2%] | 20.2h |  | 12,399 |  |
| 40 | 1.1.3.7 | Talna plošča, deb 16cm | 19.7d | 2006-04-26 A | 2006-05-20 A | 18SS+5d, 166SS+2d | 100% |  | 2006-04-25 | 2006-05-20 | 20d |  |  | MIKROARMIRANI BETON MB 30 [207.25 m3]; DELAVEC [446.4%]; VIBRATOR [53.6%]; HRUŠKA | 1142.22h | 1142.22h | 5,662,210 | 5,662,210 |
| 41 | 1.1.3.8 | **Talna plošča in stene dvigala** | 49.5d | 2006-05-03 A | 2006-07-05 A |  | 100% |  | 2006-04-12 | 2006-06-23 | 55d |  |  |  | 55.8h | 55.8h | 339,526 | 339,526 |
| 42 | 1.1.3.8.1 | • talna plošča deb. 50cm; notranje dvigalo | 1d | 2006-05-03 A | 2006-05-03 A | 15 | 100% |  | 2006-04-12 | 2006-04-13 | 1d |  |  | BETON MB 40 [2.5 m3]; DELAVEC [190.5%]; VIBRATOR [9.5%]; HRUŠKA [10%] | 21h | 21h | 74,574 | 74,574 |
| 43 | 1.1.3.8.2 | • temeljni zidovi notranjega dvigala | 1d | 2006-05-04 A | 2006-05-04 A | 42, 184SS+2d | 100% |  | 2006-05-05 | 2006-05-06 | 1d |  |  | BETON MB 40; DELAVEC [190.5%]; VIBRATOR [9.5%]; HRUŠKA [10%] | 21h | 21h | 36,937.5 | 36,937.5 |
| 44 | 1.1.3.8.3 | • talna plošča deb. 50cm; zunanje dvigalo | 0.4d | 2006-06-30 A | 2006-06-30 A | 16 | 100% |  | 2006-06-13 | 2006-06-14 | 1d |  |  | BETON MB 40; DELAVEC [200%]; VIBRATOR [10%]; HRUŠKA [10%] | 8.8h | 8.8h | 127,052 | 127,052 |
| 45 | 1.1.3.8.4 | • temeljni zidovi zunanjega dvigala | 1d | 2006-07-04 A | 2006-07-05 A | 183SS+5d | 100% |  | 2006-06-22 | 2006-06-23 | 1d |  |  | BETON MB 40 [4 m3]; DELAVEC [20%]; VIBRATOR [10%]; HRUŠKA [20%] | 5h | 5h | 100,962.5 | 100,962.5 |
| 46 | 1.1.3.9 | **Stene dvigala** | 49.9d | 2006-05-05 A | 2006-07-08 |  | 81% | 9.36d | 2006-05-06 | 2006-06-22 | 35d | 57d |  |  | 356.5h | 286h | 614,250 | 236,250 |
| 47 | 1.1.3.9.1 | • zunanje dvigalo | 3d | 2006-07-05 | 2006-07-08 | 44, 183SS+2d |  |  | 2006-06-19 | 2006-06-22 | 3d | 57d | 0d | BETON MB 40 [16 m3]; DELAVEC [200%]; VIBRATOR [15%]; HRUŠKA [20%] | 70.5h |  | 378,000 |  |
| 48 | 1.1.3.9.2 | • notranje dvigalo | 13d | 2006-05-05 A | 2006-06-27 A | 43, 184SS+2d | 100% |  | 2006-05-06 | 2006-05-23 | 13d |  |  | BETON MB 40 [11.5 m3]; DELAVEC [200%]; VIBRATOR [10%]; HRUŠKA [10%] | 286h | 286h | 236,250 | 236,250 |
| 49 | 1.1.3.10 | Stene stopnišča v 3.nadstropju | 1d | 2006-07-25 | 2006-07-26 | 186SS+1d |  |  | 2006-07-14 | 2006-07-15 | 1d | 89d | 38d | BETON MB 30 [3 m3]; DELAVEC [200%]; VIBRATOR [5%]; HRUŠKA [15%] | 22h |  | 70,875 |  |
| 50 | 1.1.3.11 | **Stebri** | 73.4d | 2006-04-18 A | 2006-07-21 |  | 87% | 9.86d | 2006-04-11 | 2006-07-11 | 70d | 93d |  |  | 1535.47h | 1304.47h | 2,311,190 | 1,927,590 |
| 51 | 1.1.3.11.1 | • prereza 0,30m3/m1 - pritličje | 23.7d | 2006-04-18 A | 2006-05-17 A | 31SS+10d, 168SS | 100% |  | 2006-04-11 | 2006-05-17 | 28d |  |  | BETON MB 40 [19.25 m3]; DELAVEC [290.6%]; VIBRATOR [9.7%]; ŽERJAV [9.7%]; ODRI do višine 4,00m [5 m2]; HRUŠKA [10%] | 758.4h | 758.4h | 467,512.5 | 467,512.5 |
| 52 | 1.1.3.11.2 | • prereza 0,30m3/m1 - 1. nadstropje | 13.8d | 2006-06-01 A | 2006-06-16 A | 69SS+3d, 169SS | 100% |  | 2006-05-19 | 2006-06-08 | 14d |  |  | BETON MB 40 [18 m3]; DELAVEC [300%]; VIBRATOR [9.5%]; ŽERJAV [9.5%]; ODRI do višine 4,00m [5 m2]; HRUŠKA [10%] | 295.27h | 295.27h | 467,512.5 | 467,512.5 |
| 53 | 1.1.3.11.3 | • prereza 0,20m3/m1 - 2. nadstropje | 7.6d | 2006-06-22 A | 2006-06-30 A | 70SS+3d, 170SS | 100% |  | 2006-06-12 | 2006-06-29 | 14d |  |  | BETON MB 40 [11.5 m3]; DELAVEC [300%]; VIBRATOR [10%]; ŽERJAV [10%]; ODRI do višine 4,00m [5 m2]; HRUŠKA [10%] | 250.8h | 250.8h | 992,565 | 992,565 |
| 54 | 1.1.3.11.4 | • prereza 0,16m3/m1 - 3. nadstropje | 7d | 2006-07-04 A | 2006-07-21 | 71SS+3d, 171SS |  | 7d | 2006-07-01 | 2006-07-11 | 7d | 93d | 0d | BETON MB 40 [9.6 m3]; DELAVEC [300%]; VIBRATOR [10%]; ŽERJAV [10%]; ODRI do višine 4,00m [5 m2]; HRUŠKA [10%] | 231h |  | 383,600 |  |

| ID | WBS | Task | Duration | Start | Finish | Predecessors | Complete | Remaining | Baseline start | Baseline finish | Baseline duration | Total slack | Free slack | Resources | Work | Actual work | Cost | Actual cost |
| --- | --- | --- | --- | --- | --- | --- | --- | --- | --- | --- | --- | --- | --- | --- | --- | --- | --- | --- |
| 55 | 1.1.3.12 | **Nosilci** | 55.3d | 2006-05-15 A | 2006-07-25 |  | 53% | 25.94d | 2006-05-04 | 2006-07-24 | 62d | 90.4d |  |  | 1782.2h | 946.2h | 7,841,137.5 | 5,500,000 |
| 56 | 1.1.3.12.1 | • nad pritličjem | 13.7d | 2006-05-15 A | 2006-06-02 A | 173SS+3d, 51SS+11d | 100% |  | 2006-05-04 | 2006-05-25 | 16d |  |  | BETON MB 40 [110.5 m3]; DELAVEC [300%]; VIBRATOR [10%]; ŽERJAV [20%]; HRUŠKA [50%] | 520.6h | 520.6h | 3,000,000 | 3,000,000 |
| 57 | 1.1.3.12.2 | • nad 1. nadstropjem | 11.2d | 2006-06-13 A | 2006-06-26 A | 174SS+4d, 52SS+5d | 100% |  | 2006-05-31 | 2006-06-16 | 14d |  |  | BETON MB 40 [18.5 m3]; DELAVEC [300%]; VIBRATOR [10%]; ŽERJAV [20%]; HRUŠKA [50%] | 425.6h | 425.6h | 2,500,000 | 2,500,000 |
| 58 | 1.1.3.12.3 | • nad 2. nadstropjem | 13d | 2006-06-17 A | 2006-07-19 | 175SS+4d, 53SS+4d |  | 13d | 2006-06-22 | 2006-07-07 | 13d | 95d | 12d | BETON MB 40 [100 m3]; DELAVEC [300%]; VIBRATOR [10%]; ŽERJAV [20%]; HRUŠKA [50%] | 494h |  | 186,637.5 |  |
| 59 | 1.1.3.12.4 | • nad 3. nadstropjem | 9d | 2006-07-13 | 2006-07-25 | 176SS+4d, 54SS+4d |  |  | 2006-07-12 | 2006-07-24 | 9d | 90.4d | 39.4d | BETON MB 40 [50 m3]; DELAVEC [300%]; VIBRATOR [10%]; ŽERJAV [20%]; HRUŠKA [50%] | 342h |  | 2,154,500 |  |
| 60 | 1.1.3.13 | **Stene** | 72.8d | 2006-03-29 A | 2006-06-30 A |  | 100% |  | 2006-03-31 | 2006-07-18 | 84d |  |  |  | 2763.4h | 2763.4h | 7,841,137.5 | 7,841,137.5 |
| 61 | 1.1.3.13.1 | • prereza 0,20m3/m2; 2. nadstropje | 1d | 2006-06-30 A | 2006-06-30 A | 178SS+2d | 100% |  | 2006-06-15 | 2006-06-24 | 7d |  |  | BETON MB 30 [8 m3]; DELAVEC [300%]; VIBRATOR [10%]; ODRI do višine 4,00m [10 m2]; ŽERJAV [10%]; HRUŠKA [30%] | 35h | 35h | 186,637.5 | 186,637.5 |
| 62 | 1.1.3.13.2 | • prereza 0,30m3/m2; pritličje, 1. nadstropje, 2. nadstropje | 71.8d | 2006-03-29 A | 2006-06-29 A | 31SS+6d, 179SS+2d | 100% |  | 2006-03-31 | 2006-07-18 | 84d |  |  | BETON MB 30 [307.5 m3]; DELAVEC [300%]; VIBRATOR [10%]; ŽERJAV [10%]; ODRI do višine 4,00m [5 m2]; HRUŠKA [60%] | 2728.4h | 2728.4h | 7,654,500 | 7,654,500 |
| 63 | 1.1.3.14 | **Ločna stena** | 1d | 2006-06-27 A | 2006-06-27 A |  | 100% |  | 2006-06-28 | 2006-06-29 | 1d |  |  |  | 22h | 22h | 106,312.5 | 106,312.5 |
| 64 | 1.1.3.14.1 | • prereza 0,20m3/m2; stena ob rampi v 2. nadstropje | 1d | 2006-06-27 A | 2006-06-27 A | 70FS+5d, 181SS+1d | 100% |  | 2006-06-28 | 2006-06-29 | 1d |  |  | BETON MB 30 [4.5 m3]; DELAVEC [200%]; VIBRATOR [5%]; ODRI do višine 4,00m [5 m2]; ŽERJAV [5%]; HRUŠKA [10%] | 22h | 22h | 106,312.5 | 106,312.5 |
| 65 | 1.1.3.15 | **Stopnice in podesti** | 23.4d | 2006-07-07 | 2006-08-04 |  |  |  | 2006-07-19 | 2006-07-26 | 5d | 52d |  |  | 55.97h |  | 196,595 |  |
| 66 | 1.1.3.15.1 | • stopnice iz 2. nadstropja v 3. nadstropje | 1d | 2006-08-04 | 2006-08-04 | 188SS+2d, 186FS+5d |  |  | 2006-07-25 | 2006-07-26 | 1d | 39d | 0d | BETON MB 40 [5 m3]; DELAVEC [300%]; VIBRATOR [10%]; ŽERJAV [10%]; HRUŠKA [20%] | 32.97h |  | 124,670 |  |
| 67 | 1.1.3.15.2 | • zunanje stopnice | 1d | 2006-07-07 | 2006-07-07 | 189SS+2d |  |  | 2006-07-19 | 2006-07-20 | 1d | 74.4d | 0d | BETON MB 40 [3 m3]; DELAVEC [200%]; VIBRATOR [10%]; ŽERJAV [10%]; HRUŠKA [10%] | 23h |  | 71,925 |  |
| 68 | 1.1.3.16 | **Plošče** | 44d | 2006-05-31 A | 2006-07-24 |  | 58% | 18.66d | 2006-05-16 | 2006-07-13 | 45d | 47d |  |  | 3476h | 2002h | 25,622,630 | 15,809,953.4 |
| 69 | 1.1.3.16.1 | • deb. 24 cm; plošča nad pritličjem | 8.6d | 2006-05-31 A | 2006-06-09 A | 56SS+9d, 191SS+5d | 100% |  | 2006-05-16 | 2006-06-06 | 15d |  |  | BETON MB 40 [383.5 m3]; DELAVEC [500%]; VIBRATOR; ČRPALKA ZA BETON; HRUŠKA [400%] | 946h | 946h | 8,633,480 | 8,633,480 |
| 70 | 1.1.3.16.2 | • deb. 24 cm; plošča nad 1.nadstropjem | 11d | 2006-06-20 A | 2006-07-03 | 57SS+7d, 192SS+5d | 87% | 1.4d | 2006-06-08 | 2006-06-22 | 11d | 63.6d | 0d | BETON MB 40 [365 m3]; DELAVEC [500%]; VIBRATOR; ČRPALKA ZA BETON; HRUŠKA [400%] | 1210h | 1056h | 8,248,820 | 7,176,473.4 |
| 71 | 1.1.3.16.3 | • deb. 24 cm; plošča nad 2.nadstropjem | 12d | 2006-07-08 | 2006-07-24 | 58SS+5d, 193SS+5d, 61 |  |  | 2006-06-28 | 2006-07-13 | 12d | -5.4d | 0d | BETON MB 40 [400 m3]; DELAVEC [500%]; VIBRATOR; ČRPALKA ZA BETON; HRUŠKA [400%] | 1320h |  | 8,740,330 |  |
| 72 | 1.1.3.17 | **Plošča nad jaškom dvigala prereza** | 14.2d | 2006-06-23 A | 2006-07-11 |  | 50% | 7.1d | 2006-05-23 | 2006-06-23 | 23d | 56.4d |  |  | 42.9h | 21.2h | 57,540 | 28,770 |
| 73 | 1.1.3.17.1 | • deb. 22 cm; notranje dvigalo | 1d | 2006-06-23 A | 2006-06-28 A | 48 | 100% |  | 2006-05-23 | 2006-05-25 | 1d |  |  | BETON MB 40 [1 m3]; DELAVEC [200%]; VIBRATOR [5%]; ŽERJAV [2%]; HRUŠKA [5%] | 21.2h | 21.2h | 28,770 | 28,770 |
| 74 | 1.1.3.17.2 | • deb. 24 cm; zunanje dvigalo | 1d | 2006-07-05 A | 2006-07-11 | 47 |  | 1d | 2006-06-22 | 2006-06-23 | 1d | 56.4d | 0d | BETON MB 40 [1 m3]; DELAVEC [200%]; VIBRATOR [5%]; ŽERJAV [2%]; HRUŠKA [10%] | 21.7h |  | 28,770 |  |
| 75 | 1.1.3.18 | **Rampe** | 3.6d | 2006-07-01 A | 2006-07-05 |  | 33% | 2.4d | 2006-06-12 | 2006-07-01 | 16d | 105.4d |  |  | 77.5h | 34.5h | 690,330 | 548,580 |
| 76 | 1.1.3.18.1 | • deb. 24 cm; zunanja rampa v 1. nadstropje | 1d | 2006-07-01 A | 2006-07-03 | 12, 19, 20, 159SS+1d |  | 1d | 2006-06-12 | 2006-06-13 | 1d | 108d | 0d | BETON MB 30 [3 m3]; DELAVEC [200%]; VIBRATOR [5%]; HRUŠKA [10%] | 21.5h |  | 70,875 |  |
| 77 | 1.1.3.18.2 | • deb. 24 cm; zunanja rampa v 2. nadstropje | 1d | 2006-07-01 A | 2006-07-03 | 12, 19, 20, 160SS+1d |  | 1d | 2006-06-12 | 2006-06-13 | 1d | 108d | 0d | BETON MB 30 [3 m3]; DELAVEC [200%]; VIBRATOR [5%]; HRUŠKA [10%] | 21.5h |  | 70,875 |  |
| 78 | 1.1.3.18.3 | • deb. 24 cm; notranja rampa | 1d | 2006-07-05 A | 2006-07-05 A | 64 | 100% |  | 2006-06-29 | 2006-07-01 | 2d |  |  | BETON MB 40 [11 m3]; DELAVEC [300%]; VIBRATOR [5%]; ŽERJAV [10%]; HRUŠKA [30%] | 34.5h | 34.5h | 548,580 | 548,580 |

| ID | WBS | Task | Duration | Start | Finish | Predecessors | Complete | Remaining | Baseline start | Baseline finish | Baseline duration | Total slack | Free slack | Resources | Work | Actual work | Cost | Actual cost |
| --- | --- | --- | --- | --- | --- | --- | --- | --- | --- | --- | --- | --- | --- | --- | --- | --- | --- | --- |
| 79 | 1.1.3.19 | **Protipotresne H vezi** | 9d | 2006-09-01 | 2006-09-13 |  |  |  | 2006-08-22 | 2006-09-02 | 9d | 13d |  |  | 8.8h |  | 235,690 |  |
| 80 | 1.1.3.19.1 | • horizontalna vez v siporeks zidu deb. 10 cm (nad vrati); 2.nadstropje | 1d | 2006-09-01 | 2006-09-02 | 108FS-2d, 206SS+1d |  |  | 2006-08-22 | 2006-08-23 | 1d | 21d | 8d | BETON MB 30 [4 m3]; DELAVEC [20%]; VIBRATOR [2%]; ŽERJAV [2%]; HRUŠKA [20%] | 4.4h |  | 98,420 |  |
| 81 | 1.1.3.19.2 | • horizontalna vez v siporeks zidu deb. 20 cm (preklada vratnih in okenskih odprtin); 2.nadstropje | 1d | 2006-09-12 | 2006-09-13 | 110SS+7d, 207SS+1d |  |  | 2006-09-01 | 2006-09-02 | 1d | 13d | 0d | BETON MB 30 [5 m3]; DELAVEC [20%]; VIBRATOR [2%]; ŽERJAV [2%]; HRUŠKA [20%] | 4.4h |  | 137,270 |  |
| 82 | 1.1.3.20 | **Vertikalne vezi** | 20d | 2006-08-08 | 2006-09-02 |  |  |  | 2006-07-28 | 2006-08-23 | 20d | 21d |  |  | 52h |  | 284,900 |  |
| 83 | 1.1.3.20.1 | • vertikalne vezi v siporeks zidu deb. 20 cm; 2. in 3.nadstropje | 20d | 2006-08-08 | 2006-09-02 | 113SS+10d, 209SS+1d |  |  | 2006-07-28 | 2006-08-23 | 20d | 21d | 8d | BETON MB 30 [10 m3]; DELAVEC [20%]; VIBRATOR [2%]; ŽERJAV [2%]; HRUŠKA [2%] | 52h |  | 284,900 |  |
| 84 | 1.1.3.21 | **Armatura** | 146.7d | 2006-03-08 A | 2006-09-13 |  | 75% | 36.86d | 2006-04-01 | 2006-09-02 | 119d | 51d |  |  | 8210h | 6191h | 32,277,240 | 24,519,247.2 |
| 85 | 1.1.3.21.1 | • GA 240/360 do fi 12 | 119d | 2006-03-10 A | 2006-09-13 | 30SS-7d, 76FF, 77FF, 67FF, 66FF, 59FF, 49FF, 35FF, 81FF, 37FF, 39FF, 45FF, 80FF | 73% | 32.1d | 2006-04-01 | 2006-09-02 | 119d | 51d |  | DELAVEC; ARMATURA [1700 kg] | 1190h | 869h | 381,840 | 278,743.2 |
| 86 | 1.1.3.21.2 | • RA 400/500 do fi 12 | 117d | 2006-03-08 A | 2006-09-13 | 30SS-7d, 76FF, 77FF, 67FF, 66FF, 59FF, 49FF, 35FF, 81FF, 37FF, 39FF, 45FF, 80FF | 76% | 28.3d | 2006-04-04 | 2006-09-02 | 117d | 51d |  | DELAVEC [150%]; ARMATURA [56000 kg] | 1755h | 1330.5h | 12,365,400 | 9,397,704 |
| 87 | 1.1.3.21.3 | • RA 400/500 nad fi 12 | 117d | 2006-03-08 A | 2006-09-13 | 30SS-7d, 76FF, 77FF, 67FF, 66FF, 59FF, 49FF, 35FF, 81FF, 37FF, 39FF, 45FF, 80FF | 76% | 28.3d | 2006-04-04 | 2006-09-02 | 117d | 51d |  | DELAVEC [450%]; ARMATURA [105000 kg] | 5265h | 3991.5h | 19,530,000 | 14,842,800 |
| 88 | 1.1.3.22 | **Armaturne mreže:** | 102d | 2006-03-15 A | 2006-07-24 |  | 81% | 19.33d | 2006-03-28 | 2006-07-28 | 95d | 91d |  |  | 2850h | 2310h | 24,354,000 | 19,726,740 |
| 89 | 1.1.3.22.1 | • MAG 500/560 | 95d | 2006-03-15 A | 2006-07-24 | 62SS-3d, 71FF | 81% | 18d | 2006-03-28 | 2006-07-28 | 95d | 91d |  | DELAVEC [300%]; ARMATURNE MREŽE [126366 kg] | 2850h | 2310h | 24,354,000 | 19,726,740 |
| 90 | 1.1.3.23 | **Svetlobni jašek** | 1d | 2006-05-11 A | 2006-05-12 A |  | 100% |  | 2006-06-08 | 2006-06-09 | 1d |  |  | BETON MB 30 [1 m3]; OPAŽ s podporami [11 m2]; DELAVEC [200%]; VIBRATOR [2%]; ARMATURA [80 kg]; HRUŠKA [5%] | 20.7h | 20.7h | 265,925 | 265,925 |
| 91 | 1.1.3.23.1 | • beton | 1d | 2006-05-11 A | 2006-05-12 A | 19FS-3d | 100% |  | 2006-06-08 | 2006-06-09 | 1d |  |  |  |  |  | 220,665 | 220,665 |
| 92 | 1.1.3.23.2 | • opaž | 1d | 2006-05-11 A | 2006-05-12 A | 19FS-3d | 100% |  | 2006-06-08 | 2006-06-09 | 1d |  |  |  |  |  | 27,500 | 27,500 |
| 93 | 1.1.3.23.3 | • armatura | 1d | 2006-05-11 A | 2006-05-12 A | 19FS-3d | 100% |  | 2006-06-08 | 2006-06-09 | 1d |  |  |  |  |  | 17,760 | 17,760 |
| 94 | 1.1.4 | **Zidarska dela** | 188.8d | 2006-03-28 A | 2006-11-25 |  | 32% | 128.9d | 2006-03-30 | 2006-11-15 | 178d | 0d |  |  | 4369.4h | 1229.1h | 74,228,324.6 | 11,991,731.48 |
| 95 | 1.1.4.1 | **HHI** | 2d | 2006-07-01 A | 2006-07-04 |  |  | 2d | 2006-05-25 | 2006-05-27 | 2d | 113d |  |  | 80h |  | 4,410,510 |  |
| 96 | 1.1.4.1.1 | • polaganje na talno ploščo | 2d | 2006-07-01 A | 2006-07-04 | 40FS+3d |  | 2d | 2006-05-25 | 2006-05-27 | 2d | 113d |  | DELAVEC [400%]; HIDROIZOLACIJA [1700 m2] | 80h |  | 4,410,510 |  |
| 97 | 1.1.4.2 | **HHI** | 4d | 2006-07-24 | 2006-07-28 |  |  |  | 2006-07-13 | 2006-07-18 | 4d | 93d |  |  | 160h |  | 6,346,190 |  |
| 98 | 1.1.4.2.1 | • parkirišča, prostor za kolesa, terasa | 4d | 2006-07-24 | 2006-07-28 | 69, 70, 71 |  |  | 2006-07-13 | 2006-07-18 | 4d | 93d |  | HIDROIZOLACIJA [2500 m2]; DELAVEC [400%] | 160h |  | 6,346,190 |  |
| 99 | 1.1.4.3 | **HHI** | 2d | 2006-07-24 | 2006-07-26 |  |  |  | 2006-07-13 | 2006-07-15 | 2d | 85d |  |  | 4h |  | 43,680 |  |
| 100 | 1.1.4.3.1 | • zunanji vhodni podest | 2d | 2006-07-24 | 2006-07-26 | 71 |  |  | 2006-07-13 | 2006-07-15 | 2d | 85d | 0d | HIDROIZOLACIJA [26 m2]; DELAVEC [20%] | 4h |  | 43,680 |  |
| 101 | 1.1.4.4 | HHI med temelji in stenami - Hidrozan | 48.8d | 2006-03-28 A | 2006-05-31 A | 31SS+1d, 62SS-1d | 100% |  | 2006-03-30 | 2006-05-27 | 45d |  |  | HIDROZAN [83 m2]; DELAVEC [5%] | 24.4h | 24.4h | 202,520 | 202,520 |
| 102 | 1.1.4.5 | **VHI** | 75.8d | 2006-03-31 A | 2006-07-07 |  | 97% | 2.61d | 2006-04-03 | 2006-06-21 | 60d | 38d |  |  | 1140h | 1120h | 1,663,200 | 1,589,280 |
| 103 | 1.1.4.5.1 | • izolacija objekta | 56d | 2006-03-31 A | 2006-06-13 A | 62SS+2d | 100% |  | 2006-04-03 | 2006-06-15 | 56d |  |  | DELAVEC [200%]; HIDROIZOLACIJA [520 m2]; ODRI do višine 4,00m [10 m2] | 1120h | 1120h | 1,589,280 | 1,589,280 |
| 104 | 1.1.4.5.2 | • izolacija zunanjega dvigala | 2d | 2006-07-05 | 2006-07-07 | 183SS+2d |  |  | 2006-06-19 | 2006-06-21 | 2d | 38d | 0d | HIDROIZOLACIJA [24 m2]; DELAVEC; ODRI do višine 10,00m [10 m2] | 20h |  | 73,920 |  |

| ID | WBS | Task | Duration | Start | Finish | Predecessors | Baseline start | Baseline finish | Baseline duration | Total slack | Free slack | Resources | Work | Cost |
| --- | --- | --- | --- | --- | --- | --- | --- | --- | --- | --- | --- | --- | --- | --- |
| 105 | 1.1.4.6 | **Zidovi iz plinobetonskih blokov deb. 10 cm** | 2d | 2006-08-07 | 2006-08-09 |  | 2006-07-27 | 2006-07-29 | 2d | 39d | 25d |  | 40h | 5,545.6 |
| 106 | 1.1.4.6.1 | • podzidava stopniščnega podesta betonskih stopnic | 2d | 2006-08-07 | 2006-08-09 | 66SS+2d | 2006-07-27 | 2006-07-29 | 2d | 39d | 0d | DELAVEC [200%]; SIPOREX 10cm [1.6 m2]; ODRI do višine 4,00m [5 m2] | 40h | 5,545.6 |
| 107 | 1.1.4.7 | **Zidovi iz plinobetonskih blokov** | 10d | 2006-08-23 | 2006-09-04 |  | 2006-08-10 | 2006-08-24 | 10d | 8d | 5d |  | 200h | 1,698,340 |
| 108 | 1.1.4.7.1 | • deb. 10 cm; 2. nadstropje | 10d | 2006-08-23 | 2006-09-04 | 193FS+2d | 2006-08-10 | 2006-08-24 | 10d | 8d | 0d | SIPOREX 10cm [500 m2]; DELAVEC [200%]; ODRI do višine 4,00m [30 m2] | 200h | 1,698,340 |
| 109 | 1.1.4.8 | **Zidovi iz plinobetonskih blokov** | 20d | 2006-08-26 | 2006-09-20 |  | 2006-08-16 | 2006-09-09 | 20d | 0d |  |  | 750h | 1,366,112 |
| 110 | 1.1.4.8.1 | • deb. 20cm | 20d | 2006-08-26 | 2006-09-20 | 193FS+5d | 2006-08-16 | 2006-09-09 | 20d | 0d |  | SIPOREX 20cm [220 m2]; DELAVEC [300%]; ODRI do višine 4,00m [30 m2] | 600h | 1,224,672 |
| 111 | 1.1.4.8.2 | • deb. 20cm; v ločni izvedbi ob rampi | 5d | 2006-08-26 | 2006-09-01 | 193FS+5d | 2006-08-16 | 2006-08-22 | 5d | 9d | 0d | SIPOREX 20cm [25 m2]; DELAVEC [300%]; ODRI do višine 4,00m [10 m2] | 150h | 141,440 |
| 112 | 1.1.4.9 | **Zidanje zidov z OMB v PCM 1:3:9** | 15d | 2006-07-26 | 2006-08-14 |  | 2006-07-15 | 2006-08-03 | 15d | 16d |  |  | 300h | 2,168,100 |
| 113 | 1.1.4.9.1 | • deb. 20cm; 2. in 3. nadstropje | 15d | 2006-07-26 | 2006-08-14 | 71FS+2d | 2006-07-15 | 2006-08-03 | 15d | 16d | 0d | OMB 20cm [495 m3]; DELAVEC [200%]; MALTA V PCM 1:3:9 [495 m2]; ODRI do višine 4,00m [30 m2]; ODRI do višine 7,00m [30 m2] | 300h | 2,168,100 |
| 114 | 1.1.4.10 | **Omet stropov (v debelini 15mm)** | 23d | 2006-09-05 | 2006-10-03 |  | 2006-08-24 | 2006-09-22 | 23d | 41d |  |  | 400h | 3,932,145 |
| 115 | 1.1.4.10.1 | • omet stropa nad 1.nadstropjem | 20d | 2006-09-08 | 2006-10-03 | 110SS+10d, 192 | 2006-08-29 | 2006-09-22 | 20d | 41d |  | DELAVEC; OMET V PCM 1:2:6 [33 m2]; ODRI do višine 4,00m [33 m2] | 200h | 93,555 |
| 116 | 1.1.4.10.2 | • omet stropa nad 2.nadstropjem; stanovanja brez WC in kopalnic, ter pod balkoni | 20d | 2006-09-05 | 2006-09-29 | 193, 108SS+10d | 2006-08-24 | 2006-09-19 | 20d | 44d |  | DELAVEC; OMET V PCM 1:2:6 [1333 m2]; ODRI do višine 4,00m [1333 m2] | 200h | 3,779,055 |
| 117 | 1.1.4.11 | **Osnovni fasadni nanos (lepilna malta, steklena mrežica)** | 15d | 2006-08-21 | 2006-09-07 |  | 2006-08-08 | 2006-08-29 | 15d | 61d |  |  | 150h | 6,273,288 |
| 118 | 1.1.4.11.1 | • nosilci nad pritličjem | 15d | 2006-08-21 | 2006-09-07 | 193 | 2006-08-08 | 2006-08-29 | 15d | 61d |  | DELAVEC [25%]; STEKLENA MREŽICA [612 m2]; LEPILNA MALTA [612 m2]; ODRI do višine 4,00m [612 m2] | 37.5h | 1,388,016 |
| 119 | 1.1.4.11.2 | • nosilci nad 1. nadstropjem; | 15d | 2006-08-21 | 2006-09-07 | 193 | 2006-08-08 | 2006-08-29 | 15d | 61d |  | DELAVEC [25%]; STEKLENA MREŽICA [252 m2]; LEPILNA MALTA [252 m2]; ODRI do višine 4,00m [252 m2] | 37.5h | 571,536 |
| 120 | 1.1.4.11.3 | • nosilci nad 2. nadstropjem; | 15d | 2006-08-21 | 2006-09-07 | 193 | 2006-08-08 | 2006-08-29 | 15d | 61d |  | DELAVEC [25%]; STEKLENA MREŽICA [510 m2]; LEPILNA MALTA [510 m2]; ODRI do višine 4,00m [510 m2] | 37.5h | 1,154,412 |
| 121 | 1.1.4.11.4 | • strop nad pritličjem, 1.nadstropju in 2.nadstropju (stropovi nad parkirišči se ne omečejo) | 15d | 2006-08-21 | 2006-09-07 | 193 | 2006-08-08 | 2006-08-29 | 15d | 61d |  | DELAVEC [25%]; STEKLENA MREŽICA [1390 m2]; LEPILNA MALTA [1390 m2]; ODRI do višine 4,00m [1390 m2] | 37.5h | 3,159,324 |
| 122 | 1.1.4.12 | **Omet sten (v debelini 15mm)** | 37d | 2006-08-02 | 2006-09-18 |  | 2006-07-21 | 2006-09-07 | 37d | 9d | 0d |  | 132.5h | 2,893,330 |
| 123 | 1.1.4.12.1 | • stanovanja v 2. in 3. nadstropju | 30d | 2006-08-02 | 2006-09-08 | 113SS+5d | 2006-07-21 | 2006-08-30 | 30d | 16d |  | DELAVEC [25%]; OMET V PCM 1:2:6 [1750 m2]; ODRI do višine 4,00m [1750 m2] | 75h | 2,786,465 |
| 124 | 1.1.4.12.2 | • zid iz plinobetonskih blokov v ločni izvedbi ob rampi | 3d | 2006-09-14 | 2006-09-18 | 111SS+15d | 2006-09-04 | 2006-09-07 | 3d | 9d |  | DELAVEC [25%]; OMET V PCM 1:2:6 [46 m2]; ODRI do višine 4,00m [46 m2] | 7.5h | 73,370 |
| 125 | 1.1.4.12.3 | • notranje AB stene stopnišča nad 2. nadstropjem | 4d | 2006-08-02 | 2006-08-07 | 113SS+5d | 2006-07-21 | 2006-07-27 | 4d | 42d |  | DELAVEC [125%]; OMET V PCM 1:2:6 [21 m2]; ODRI do višine 4,00m [21 m2] | 50h | 33,495 |
| 126 | 1.1.4.13 | Ekspandirani polistiren (100 kPa) | 10d | 2006-08-11 | 2006-08-25 | 188FS+4d | 2006-08-01 | 2006-08-14 | 10d | 11d | 0d | DELAVEC; POLISTIREN [3570 m2] | 100h | 4,782,742 |
| 127 | 1.1.4.14 | **Elastificirani ekspandirani polistiren, polaganje PE folije** | 15d | 2006-09-14 | 2006-10-03 |  | 2006-09-04 | 2006-09-22 | 15d | 0d |  |  | 150h | 1,060,170 |
| 128 | 1.1.4.14.1 | • deb. 2,2 /2,0 cm | 15d | 2006-09-14 | 2006-10-03 | 108, 110SS+15d, 111, 113 | 2006-09-04 | 2006-09-22 | 15d | 0d |  | DELAVEC [50%]; POLISTIREN [1592 m2] | 75h | 939,280 |
| 129 | 1.1.4.14.2 | • deb. 3,2 /3,0 cm | 15d | 2006-09-14 | 2006-10-03 | 108, 110SS+15d, 111, 113 | 2006-09-04 | 2006-09-22 | 15d | 0d |  | DELAVEC [50%]; POLISTIREN [157 m2] | 75h | 120,890 |

| ID | WBS | Task | Duration | Start | Finish | Predecessors | Complete | Remaining | Baseline start | Baseline finish | Baseline duration | Total slack | Free slack | Resources | Work | Actual work | Cost | Actual cost |
| --- | --- | --- | --- | --- | --- | --- | --- | --- | --- | --- | --- | --- | --- | --- | --- | --- | --- | --- |
| 130 | 1.1.4.15 | **Ekstrudirani polistiren** | 75.2d | 2006-04-03 A | 2006-07-08 |  | 98% | 1.34d | 2006-04-06 | 2006-06-22 | 58d | 38d |  |  | 28h | 27.5h | 1,130,800 | 1,064,800 |
| 131 | 1.1.4.15.1 | • deb. 6 cm; ob objektu | 55d | 2006-04-03 A | 2006-06-13 A | 20SS | 100% |  | 2006-04-06 | 2006-06-03 | 43d |  |  | DELAVEC [5%]; POLISTIREN [440 m2] | 27.5h | 27.5h | 1,064,800 | 1,064,800 |
| 132 | 1.1.4.15.2 | • deb. 6 cm; ob zunanjem dvigalu | 1d | 2006-07-07 | 2006-07-08 | 104 |  |  | 2006-06-21 | 2006-06-22 | 1d | 38d | 0d | DELAVEC [5%]; POLISTIREN [22 m2] | 0.5h |  | 66,000 |  |
| 133 | 1.1.4.16 | Mikroarmirani cementni estrih | 7d | 2006-10-03 | 2006-10-11 | 128, 129 |  |  | 2006-09-22 | 2006-10-02 | 7d | 0d |  | DELAVEC; PE FOLIJA [4070 m2]; MIKROARMIRANI CEMENTNI ESTRIH [4070 m2]; VIBRATOR [5%] | 73.5h |  | 8,445,500 |  |
| 134 | 1.1.4.17 | **Naklonski mikroarmirani cementni estrih** | 10d | 2006-09-18 | 2006-09-30 |  |  |  | 2006-09-07 | 2006-09-20 | 10d | 43d |  |  | 140h |  | 4,360,385 |  |
| 135 | 1.1.4.17.1 | • deb. 3 - 7cm | 10d | 2006-09-18 | 2006-09-30 | 128SS+3d |  |  | 2006-09-07 | 2006-09-20 | 10d | 43d | 0d | DELAVEC [22.5%]; PE FOLIJA [2015 m2]; MIKROARMIRANI CEMENTNI ESTRIH [2015 m2]; VIBRATOR [7.5%] | 30h |  | 4,050,150 |  |
| 136 | 1.1.4.17.2 | • deb. 5 - 8cm; zun.podest | 10d | 2006-09-18 | 2006-09-30 | 128SS+3d |  |  | 2006-09-07 | 2006-09-20 | 10d | 43d |  | DELAVEC [30%]; PE FOLIJA [2015 m2]; MIKROARMIRANI CEMENTNI ESTRIH [2015 m2]; VIBRATOR [10%] | 40h |  | 59,020 |  |
| 137 | 1.1.4.17.3 | • deb. 6 - 8cm | 10d | 2006-09-18 | 2006-09-30 | 128SS+3d |  |  | 2006-09-07 | 2006-09-20 | 10d | 43d | 0d | DELAVEC [30%]; PE FOLIJA [47 m2]; VIBRATOR [5%]; MIKROARMIRANI CEMENTNI ESTRIH [47 m2] | 35h |  | 108,805 |  |
| 138 | 1.1.4.17.4 | • deb. 8 - 11cm; balkoni | 10d | 2006-09-18 | 2006-09-30 | 128SS+3d |  |  | 2006-09-07 | 2006-09-20 | 10d | 43d |  | DELAVEC [30%]; VIBRATOR [5%]; PE FOLIJA [47 m2]; MIKROARMIRANI CEMENTNI ESTRIH [47 m2] | 35h |  | 142,410 |  |
| 139 | 1.1.4.18 | **Naklonski beton** | 10d | 2006-07-26 | 2006-08-08 |  |  |  | 2006-07-15 | 2006-07-28 | 10d | 85d |  |  | 20h |  | 37,260 |  |
| 140 | 1.1.4.18.1 | • deb. 2 - 4cm; vhodne niše stanovanj v 3. nadstropje | 10d | 2006-07-26 | 2006-08-08 | 100 |  |  | 2006-07-15 | 2006-07-28 | 10d | 85d | 0d | NAKLONSKI BETON [23 m2]; PE FOLIJA [23 m2]; DELAVEC [20%] | 20h |  | 37,260 |  |
| 141 | 1.1.4.19 | **Kombi plošče (Novolit)** | 46d | 2006-05-25 A | 2006-07-22 |  | 62% | 17.4d | 2006-05-15 | 2006-07-13 | 46d | 97.6d |  |  | 92h | 57.2h | 14,409,954 | 8,934,171.48 |
| 142 | 1.1.4.19.1 | • deb. 12,5cm | 46d | 2006-05-25 A | 2006-07-22 | 191SS+4d, 71FF-1d | 62% | 17.4d | 2006-05-15 | 2006-07-13 | 46d | 97.6d |  | DELAVEC [20%]; KOMBI PLOŠČE 12,5cm [3050 m2] | 92h | 57.2h | 14,409,954 | 8,934,171.48 |
| 143 | 1.1.4.20 | **Troslojne lahke gradbene plošče** | 54d | 2006-07-01 | 2006-09-07 |  |  |  | 2006-07-04 | 2006-08-29 | 43d | 61d |  |  | 45h |  | 3,781,038 |  |
| 144 | 1.1.4.20.1 | • deb. 5cm; v pritličju | 15d | 2006-07-01 | 2006-07-20 | 191 |  |  | 2006-07-04 | 2006-07-24 | 15d | 100d |  | DELAVEC [10%]; KOMBI PLOŠČE 5cm [578 m2]; ODRI do višine 4,00m [578 m2] | 15h |  | 1,790,644 |  |
| 145 | 1.1.4.20.2 | • deb. 5cm; v 1. nadstropju | 15d | 2006-07-25 | 2006-08-11 | 192 |  |  | 2006-07-18 | 2006-08-05 | 15d | 81.6d |  | DELAVEC [10%]; KOMBI PLOŠČE 5cm [237 m2]; ODRI do višine 4,00m [237 m2] | 15h |  | 734,226 |  |
| 146 | 1.1.4.20.3 | • deb. 5cm; v 2. nadstropju | 15d | 2006-08-21 | 2006-09-07 | 193 |  |  | 2006-08-08 | 2006-08-29 | 15d | 61d |  | DELAVEC [10%]; KOMBI PLOŠČE 5cm [316 m2]; ODRI do višine 4,00m [316 m2] | 15h |  | 978,968 |  |
| 147 | 1.1.4.21 | Zaključno čiščenje objekta | 6d | 2006-11-18 | 2006-11-25 | 252, 27, 297, 273, 289, 292 |  |  | 2006-11-08 | 2006-11-15 | 6d | 0d |  | DELAVEC [395.1%]; ŽERJAV [4.9%] | 240h |  | 1,341,315 |  |
| 148 | 1.1.4.22 | **Preboji v stenah iz plinobetonskih blokov deb. 20 cm (ø 155mm)** | 20d | 2006-08-26 | 2006-09-20 |  |  |  | 2006-08-16 | 2006-09-09 | 20d | 51d |  |  | 20h |  | 97,200 |  |
| 149 | 1.1.4.22.1 | • stanovanja v 2. nadstropju | 20d | 2006-08-26 | 2006-09-20 | 108SS+3d, 113SS+4d |  |  | 2006-08-16 | 2006-09-09 | 20d | 51d |  | DELAVEC [10%]; ODRI do višine 4,00m [3 m2]; ODRI do višine 7,00m [3 m2] | 20h |  | 97,200 |  |
| 150 | 1.1.4.23 | **Dimnik z RF tuljavo** | 10d | 2006-07-10 | 2006-07-21 |  |  |  | 2006-07-21 | 2006-08-03 | 10d | 98.4d |  |  | 80h |  | 3,151,000 |  |
| 151 | 1.1.4.23.1 | • dimnik višine 8,00m; z dvojnim priključkom - eden v 2. etaži in eden v 3. etaži; dimnik ø 160mm | 10d | 2006-07-10 | 2006-07-21 | 275 |  |  | 2006-07-21 | 2006-08-03 | 10d | 98.4d |  | DELAVEC [30%]; ŽERJAV [10%]; DIMNIK [8 m']; ODRI do višine 4,00m [5 m2] | 40h |  | 1,908,000 |  |
| 152 | 1.1.4.23.2 | • dimnik višine 4,60m; z enojnim priključkom v 3. etaži; dimnik ø 140mm | 10d | 2006-07-10 | 2006-07-21 | 275 |  |  | 2006-07-21 | 2006-08-03 | 10d | 98.4d |  | DELAVEC [30%]; ŽERJAV [10%]; DIMNIK [4.6 m']; ODRI do višine 4,00m [5 m2] | 40h |  | 1,243,000 |  |
| 153 | 1.1.5 | **Tesarska dela** | 158d | 2006-03-15 A | 2006-10-03 |  | 64% | 57.31d | 2006-03-18 | 2006-09-22 | 146d | 41d |  |  | 7672.6h | 6218.36h | 41,410,708 | 27,489,075.6 |
| 154 | 1.1.5.1 | **Opaž pasovnih temeljev** | 46d | 2006-03-16 A | 2006-05-13 A |  | 100% |  | 2006-03-20 | 2006-05-18 | 46d |  |  |  | 912h | 912h | 2,441,250 | 2,441,250 |
| 155 | 1.1.5.1.1 | • temeljna peta | 45d | 2006-03-16 A | 2006-05-12 A | 30SS-1d | 100% |  | 2006-03-20 | 2006-05-17 | 45d |  |  | OPAŽ s podporami [370 m2]; DELAVEC [95.2%]; ŽERJAV [4.8%] | 450h | 450h | 802,900 | 802,900 |
| 156 | 1.1.5.1.2 | • temeljna greda | 44d | 2006-03-18 A | 2006-05-13 A | 31SS-1d | 100% |  | 2006-03-22 | 2006-05-18 | 44d |  |  | OPAŽ s podporami [755 m2]; ŽERJAV [5%]; DELAVEC | 462h | 462h | 1,638,350 | 1,638,350 |
| 157 | 1.1.5.2 | Opaž točkovnih temeljev | 43d | 2006-03-15 A | 2006-05-09 A | 32SS-2d | 100% |  | 2006-03-18 | 2006-05-12 | 43d |  |  | OPAŽ s podporami [125 m2]; DELAVEC [20%] | 86h | 86h | 271,250 | 271,250 |

| ID | WBS | Task | Duration | Start | Finish | Predecessors | Complete | Remaining | Baseline start | Baseline finish | Baseline duration | Total slack | Free slack | Resources | Work | Actual work | Cost | Actual cost |
| --- | --- | --- | --- | --- | --- | --- | --- | --- | --- | --- | --- | --- | --- | --- | --- | --- | --- | --- |
| 158 | 1.1.5.3 | **Opaž pasovnih temeljev** | 3d | 2006-07-01 A | 2006-07-05 |  |  | 3d | 2006-05-20 | 2006-05-25 | 3d | 0d |  |  | 63h |  | 78,120 |  |
| 159 | 1.1.5.3.1 | • temelji za rampe; v 1. nadstropje | 3d | 2006-07-01 A | 2006-07-05 | 42SS+30d |  | 3d | 2006-05-20 | 2006-05-25 | 3d | -3d | 0d | OPAŽ s podporami [16 m2]; DELAVEC; ŽERJAV [5%] | 31.5h |  | 39,060 |  |
| 160 | 1.1.5.3.2 | • temelji za rampe; v 2. nadstropje | 3d | 2006-07-01 A | 2006-07-05 | 42SS+30d |  | 3d | 2006-05-20 | 2006-05-25 | 3d | -3d | 0d | OPAŽ s podporami [20 m2]; DELAVEC; ŽERJAV [5%] | 31.5h |  | 39,060 |  |
| 161 | 1.1.5.4 | **Opaž pasovnih temeljev z opornim zidom, temelja ramp in stopnic** | 3d | 2006-07-01 A | 2006-07-05 |  |  | 3d | 2006-06-12 | 2006-06-15 | 3d | 112d |  |  | 15.3h |  | 39,494 |  |
| 162 | 1.1.5.4.1 | • pred vhodom v trgovino | 3d | 2006-07-01 A | 2006-07-05 | 19 |  | 3d | 2006-06-12 | 2006-06-15 | 3d | 112d | 0d | DELAVEC [50%]; OPAŽ s podporami [18.2 m2]; ŽERJAV [1%] | 15.3h |  | 39,494 |  |
| 163 | 1.1.5.5 | **Opaž zunanjih stopnic** | 5d | 2006-07-01 A | 2006-07-07 |  |  | 5d | 2006-06-12 | 2006-06-19 | 5d | 75d |  |  | 10h |  | 6,880 |  |
| 164 | 1.1.5.5.1 | • pred vhodom v trgovino | 5d | 2006-07-01 A | 2006-07-07 | 19 |  | 5d | 2006-06-12 | 2006-06-19 | 5d | 75d | 0d | OPAŽ s podporami [1 m2]; DELAVEC [20%] | 10h |  | 6,880 |  |
| 165 | 1.1.5.6 | **Opaž talne plošče** | 22d | 2006-04-21 A | 2006-05-19 A |  | 100% |  | 2006-04-21 | 2006-05-20 | 22d |  |  |  | 22h | 22h | 147,875 | 147,875 |
| 166 | 1.1.5.6.1 | • deb. 16cm | 22d | 2006-04-21 A | 2006-05-19 A | 18SS+3d | 100% |  | 2006-04-21 | 2006-05-20 | 22d |  |  | DELAVEC [10%]; OPAŽ s podporami [28 m2] | 22h | 22h | 147,875 | 147,875 |
| 167 | 1.1.5.7 | **Opaž stebrov** | 66d | 2006-04-18 A | 2006-07-12 |  | 87% | 8.87d | 2006-04-11 | 2006-07-07 | 68d | 106.4d |  |  | 274.7h | 236.2h | 2,783,880 | 2,421,975.6 |
| 168 | 1.1.5.7.1 | • prereza 0,30m3/m1 - pritličje | 23.7d | 2006-04-18 A | 2006-05-17 A | 32SS+16d | 100% |  | 2006-04-11 | 2006-05-17 | 28d |  |  | OPAŽ s podporami [140 m2]; DELAVEC [45.5%]; ŽERJAV [4.5%]; ODRI do višine 4,00m [5 m2] | 118.5h | 118.5h |  |  |
| 169 | 1.1.5.7.2 | • prereza 0,30m3/m1 - 1. nadstropje | 13.8d | 2006-06-01 A | 2006-06-16 A | 69SS+1d | 100% |  | 2006-05-17 | 2006-06-06 | 14d |  |  | OPAŽ s podporami [140 m2]; DELAVEC [50%]; ŽERJAV [5%]; ODRI do višine 4,00m [5 m2] | 75.9h | 75.9h |  |  |
| 170 | 1.1.5.7.3 | • prereza 0,20m3/m1 - 2. nadstropje | 7.6d | 2006-06-22 A | 2006-06-30 A | 70SS+1d | 100% |  | 2006-06-09 | 2006-06-27 | 14d |  |  | OPAŽ s podporami [120 m2]; DELAVEC [50%]; ŽERJAV [5%]; ODRI do višine 4,00m [5 m2] | 41.8h | 41.8h |  |  |
| 171 | 1.1.5.7.4 | • prereza 0,16m3/m1 - 3. nadstropje | 7d | 2006-07-04 A | 2006-07-12 | 71SS+1d |  | 7d | 2006-06-29 | 2006-07-07 | 7d | 106.4d | 0d | OPAŽ s podporami [100 m2]; DELAVEC [50%]; ŽERJAV [5%]; ODRI do višine 4,00m [5 m2] | 38.5h |  |  |  |
| 172 | 1.1.5.8 | **Opaž nosilcev** | 51.9d | 2006-05-13 A | 2006-07-19 |  | 69% | 15.95d | 2006-05-01 | 2006-07-18 | 61d | 100.4d |  |  | 2239.65h | 1551.15h | 11,016,720 | 7,601,536.8 |
| 173 | 1.1.5.8.1 | • nad pritličjem | 14.9d | 2006-05-13 A | 2006-06-03 A | 51SS+15d | 100% |  | 2006-05-01 | 2006-05-20 | 16d |  |  | OPAŽ s podporami [643.92 m2]; DELAVEC [400%]; ŽERJAV [5%]; ODRI do višine 4,00m [14.97 m2] | 603.45h | 603.45h |  |  |
| 174 | 1.1.5.8.2 | • nad 1. nadstropjem | 20.4d | 2006-06-07 A | 2006-06-30 A | 52SS+3d | 100% |  | 2006-05-23 | 2006-06-11 | 13d |  |  | OPAŽ s podporami [860 m2]; DELAVEC [400%]; ŽERJAV [5%]; ODRI do višine 4,00m [20 m2] | 826.2h | 826.2h |  |  |
| 175 | 1.1.5.8.3 | • nad 2. nadstropjem | 11d | 2006-06-28 A | 2006-07-11 | 53SS+4d | 27% | 8d | 2006-06-16 | 2006-06-30 | 11d | 107d | 0d | OPAŽ s podporami [715 m2]; DELAVEC [400%]; ŽERJAV [5%]; ODRI do višine 4,00m [20 m2] | 445.5h | 121.5h |  |  |
| 176 | 1.1.5.8.4 | • nad 3. nadstropjem | 9d | 2006-07-08 | 2006-07-19 | 54SS+4d |  |  | 2006-07-06 | 2006-07-18 | 9d | 90.4d | 0d | OPAŽ s podporami [425 m2]; DELAVEC [400%]; ŽERJAV [5%]; ODRI do višine 4,00m [20 m2] | 364.5h |  |  |  |
| 177 | 1.1.5.9 | **Opaž stene** | 79.6d | 2006-03-21 A | 2006-07-01 A |  | 100% |  | 2006-03-24 | 2006-07-14 | 86d |  |  |  | 1879.1h | 1879.1h | 5,061,120 | 5,061,120 |
| 178 | 1.1.5.9.1 | • prereza 0,20 m3/m2; 2. nadstropje | 2.6d | 2006-06-29 A | 2006-07-01 A | 70SS+4d | 100% |  | 2006-06-13 | 2006-06-24 | 9d |  |  | OPAŽ s podporami [46.8 m2]; DELAVEC [600%]; ŽERJAV [45%]; ODRI do višine 4,00m [11.56 m2] | 167.7h | 167.7h | 207,360 | 207,360 |
| 179 | 1.1.5.9.2 | • prereza 0,30 m3/m2; pritličje, 1. nadstropje, 2. nadstropje | 79.6d | 2006-03-21 A | 2006-07-01 A | 31SS+1d | 100% |  | 2006-03-24 | 2006-07-14 | 86d |  |  | OPAŽ s podporami [1758.6 m2]; DELAVEC [200%]; ŽERJAV [15%]; ODRI do višine 4,00m [18.51 m2] | 1711.4h | 1711.4h | 4,853,760 | 4,853,760 |
| 180 | 1.1.5.10 | **Opaž ločne stene** | 3d | 2006-06-23 A | 2006-06-27 A |  | 100% |  | 2006-06-26 | 2006-06-29 | 3d |  |  |  | 13.5h | 13.5h | 304,090 | 304,090 |
| 181 | 1.1.5.10.1 | • prereza 0,20 m3/m2; 1. nadstropje | 3d | 2006-06-23 A | 2006-06-27 A | 70FS+3d | 100% |  | 2006-06-26 | 2006-06-29 | 3d |  |  | OPAŽ s podporami [47 m2]; DELAVEC [40%]; ŽERJAV [5%] | 13.5h | 13.5h | 304,090 | 304,090 |

| ID | WBS | Task | Duration | Start | Finish | Predecessors | Complete | Remaining | Baseline start | Baseline finish | Baseline duration | Total slack | Free slack | Resources | Work | Actual work | Cost | Actual cost |
| --- | --- | --- | --- | --- | --- | --- | --- | --- | --- | --- | --- | --- | --- | --- | --- | --- | --- | --- |
| 182 | 1.1.5.11 | **Opaž sten dvigala** | 48.9d | 2006-05-04 A | 2006-07-06 |  | 93% | 3.2d | 2006-05-03 | 2006-06-20 | 36d | 38d |  |  | 328.95h | 235.95h | 831,220 | 307,970 |
| 183 | 1.1.5.11.1 | • zunanje dvigalo | 3d | 2006-07-03 | 2006-07-06 | 44FS+1d |  |  | 2006-06-15 | 2006-06-20 | 3d | 38d | 0d | DELAVEC [300%]; OPAŽ s podporami [175 m2]; ŽERJAV [10%]; ODRI do višine 4,00m [20 m2] | 93h |  | 523,250 |  |
| 184 | 1.1.5.11.2 | • notranje dvigalo | 42.9d | 2006-05-04 A | 2006-06-28 A | 179SS+30d | 100% |  | 2006-05-03 | 2006-05-20 | 14d |  |  | OPAŽ s podporami [103 m2]; DELAVEC [50%]; ŽERJAV [5%]; ODRI do višine 4,00m [10 m2] | 235.95h | 235.95h | 307,970 | 307,970 |
| 185 | 1.1.5.12 | **Opaž sten stopnišča v 3.nadstropje** | 3d | 2006-07-24 | 2006-07-27 |  |  |  | 2006-07-13 | 2006-07-17 | 3d | 11d |  |  | 10.5h |  | 76,800 |  |
| 186 | 1.1.5.12.1 | • zidovi stopnišča 3. nadstropja | 3d | 2006-07-24 | 2006-07-27 | 71 |  |  | 2006-07-13 | 2006-07-17 | 3d | 11d | 0d | OPAŽ s podporami [30 m2]; DELAVEC [30%]; ŽERJAV [5%]; ODRI do višine 4,00m [10 m2] | 10.5h |  | 76,800 |  |
| 187 | 1.1.5.13 | **Opaž stopnic in podestov** | 26.4d | 2006-07-05 | 2006-08-07 |  |  |  | 2006-07-17 | 2006-07-27 | 8d | 33.4d |  |  | 42.8h |  | 261,440 |  |
| 188 | 1.1.5.13.1 | • notranje stopnice iz 2. nadstropja v 3. nadstropje | 4d | 2006-08-02 | 2006-08-07 | 186FS+4d |  |  | 2006-07-21 | 2006-07-27 | 4d | 11d | 0d | OPAŽ s podporami [22 m2]; DELAVEC [50%]; ŽERJAV [5%]; ODRI do višine 4,00m [10 m2] | 22h |  | 151,360 |  |
| 189 | 1.1.5.13.2 | • zunanje stopnice | 4d | 2006-07-05 | 2006-07-10 | 179FS+2d |  |  | 2006-07-17 | 2006-07-21 | 4d | 74.4d | 0d | OPAŽ s podporami [16 m2]; DELAVEC [50%]; ŽERJAV [2%]; ODRI do višine 4,00m [20 m2] | 20.8h |  | 110,080 |  |
| 190 | 1.1.5.14 | **Opaž plošč** | 69.1d | 2006-05-23 A | 2006-08-21 |  | 63% | 25.82d | 2006-05-09 | 2006-08-08 | 71d | -5.4d | 0d |  | 1619h | 1239h | 12,238,940 | 7,815,446 |
| 191 | 1.1.5.14.1 | • deb. 24 cm; plošča nad pritličjem (s podpiranjem do 4,00m) | 30.1d | 2006-05-23 A | 2006-06-30 A | 173SS+7d | 100% |  | 2006-05-09 | 2006-07-04 | 43d |  |  | OPAŽ s podporami [1500 m2]; DELAVEC [300%]; ODRI do višine 4,00m [1500 m2] | 903h | 903h | 3,870,200 | 3,870,200 |
| 192 | 1.1.5.14.2 | • deb. 24 cm; plošča nad 1. nadstropjem (s podpiranjem do 3,30m) | 33.6d | 2006-06-13 A | 2006-07-24 A | 174SS+4d | 100% |  | 2006-05-31 | 2006-07-18 | 39d |  |  | OPAŽ s podporami [1500 m2]; DELAVEC; ODRI do višine 4,00m [1500 m2] | 336h | 336h | 3,938,190 | 3,938,190 |
| 193 | 1.1.5.14.3 | • deb. 24 cm; plošča nad 2. nadstropjem (s podpiranjem do 3,30m) | 38d | 2006-07-03 | 2006-08-21 | 175SS+4d |  |  | 2006-06-22 | 2006-08-08 | 38d | -5.4d | 0d | OPAŽ s podporami [1700 m2]; DELAVEC; ODRI do višine 4,00m [1700 m2] | 380h |  | 4,419,350 |  |
| 194 | 1.1.5.15 | **Opaž rampe** | 3d | 2006-07-04 A | 2006-07-06 |  |  | 3d | 2006-06-29 | 2006-07-03 | 3d | 110.4d |  |  | 15h |  | 305,020 |  |
| 195 | 1.1.5.15.1 | • deb. 24 cm; rampa v objektu | 3d | 2006-07-04 A | 2006-07-06 | 181 |  | 3d | 2006-06-29 | 2006-07-03 | 3d | 110.4d |  | OPAŽ s podporami [101 m2]; DELAVEC [50%]; ODRI do višine 4,00m [20 m2] | 15h |  | 305,020 |  |
| 196 | 1.1.5.16 | **Opaž roba plošče** | 54d | 2006-05-23 A | 2006-07-31 |  | 53% | 25.48d | 2006-05-09 | 2006-07-18 | 54d | 91.1d |  |  | 57h | 30.1h | 614,120 | 332,550.4 |
| 197 | 1.1.5.16.1 | • rob plošče višine 24cm | 54d | 2006-05-23 A | 2006-07-31 | 191SS | 56% | 23.9d | 2006-05-09 | 2006-07-18 | 54d | 91.1d |  | OPAŽ s podporami [137 m2]; DELAVEC [10%] | 54h | 30.1h | 593,840 | 332,550.4 |
| 198 | 1.1.5.16.2 | • rob zunanjih ramp višine 15cm | 3d | 2006-07-03 | 2006-07-06 | 76, 77 |  |  | 2006-06-13 | 2006-06-16 | 3d | 111d |  | OPAŽ s podporami [3.6 m2]; DELAVEC [10%] | 3h |  | 20,280 |  |
| 199 | 1.1.5.17 | **Opaž plošče za jaške dvigala z zunanjim robom plošče** | 12.2d | 2006-06-22 A | 2006-07-06 |  | 50% | 6.1d | 2006-05-22 | 2006-06-24 | 25d | 110.4d |  |  | 6h | 3h | 32,314 | 16,912 |
| 200 | 1.1.5.17.1 | • deb. 22 cm; notranje dvigalo | 3d | 2006-06-22 A | 2006-06-26 A | 73SS-1d | 100% |  | 2006-05-22 | 2006-05-26 | 3d |  |  | OPAŽ s podporami [5.6 m2]; DELAVEC [10%] | 3h | 3h | 16,912 | 16,912 |
| 201 | 1.1.5.17.2 | • deb. 25 cm; zunanje dvigalo | 3d | 2006-07-04 | 2006-07-06 | 74SS-1d |  |  | 2006-06-21 | 2006-06-24 | 3d | 110.4d |  | OPAŽ s podporami [5.1 m2]; DELAVEC [10%] | 3h |  | 15,402 |  |
| 202 | 1.1.5.18 | **Opaž roba talne plošče dvigala v višini 50cm** | 40.3d | 2006-05-03 A | 2006-06-23 A |  | 100% |  | 2006-04-13 | 2006-06-19 | 50d |  |  |  | 3.3h | 3.3h | 13,910 | 13,910 |
| 203 | 1.1.5.18.1 | • notranje dvigalo | 3d | 2006-05-03 A | 2006-05-05 A | 42 | 100% |  | 2006-04-13 | 2006-04-17 | 3d |  |  | OPAŽ s podporami [4.7 m2]; DELAVEC [4.2%]; ŽERJAV [0.8%] | 1.5h | 1.5h | 6,110 | 6,110 |
| 204 | 1.1.5.18.2 | • zunanje dvigalo | 3d | 2006-06-21 A | 2006-06-23 A | 44 | 100% |  | 2006-06-14 | 2006-06-19 | 3d |  |  | OPAŽ s podporami [5 m2]; DELAVEC [5%]; ŽERJAV [1%] | 1.8h | 1.8h | 7,800 | 7,800 |
| 205 | 1.1.5.19 | **Opaž protipotresne horizonzalne vezi prereza** | 10d | 2006-08-30 | 2006-09-12 |  |  |  | 2006-08-19 | 2006-09-01 | 10d | 13d |  |  | 20h |  | 777,450 |  |
| 206 | 1.1.5.19.1 | • H vez v siporeks zidu deb. 10 cm (nad vrati); 2. nadstropje | 1d | 2006-08-30 | 2006-08-31 | 108SS+6d |  |  | 2006-08-19 | 2006-08-21 | 1d | 22d | 1d | OPAŽ s podporami [80 m2]; DELAVEC; ODRI do višine 4,00m [60 m2] | 10h |  | 432,525 |  |
| 207 | 1.1.5.19.2 | • H vez v siporeks zidu deb. 20 cm (preklada vratnih in okenskih odprtin); 2. nadstropje | 1d | 2006-09-11 | 2006-09-12 | 110SS+12d |  |  | 2006-08-31 | 2006-09-01 | 1d | 13d | 0d | OPAŽ s podporami [63 m2]; DELAVEC; ODRI do višine 4,00m [60 m2] | 10h |  | 344,925 |  |

| ID | WBS | Task | Duration | Start | Finish | Predecessors | Complete | Remaining | Baseline start | Baseline finish | Baseline duration | Total slack | Free slack | Resources | Work | Actual work | Cost | Actual cost |
| --- | --- | --- | --- | --- | --- | --- | --- | --- | --- | --- | --- | --- | --- | --- | --- | --- | --- | --- |
| 208 | 1.1.5.20 | **Opaž V vezi** | 22d | 2006-07-28 | 2006-08-26 |  |  |  | 2006-07-18 | 2006-08-16 | 22d | 28d |  |  | 46.2h |  | 465,375 |  |
| 209 | 1.1.5.20.1 | • vertikalne vezi v siporeks zidu deb. 20 cm; 2. in 3. nadstropje | 22d | 2006-07-28 | 2006-08-26 | 113SS+2d |  |  | 2006-07-18 | 2006-08-16 | 22d | 28d | 7d | OPAŽ s podporami [85 m2]; DELAVEC [20%]; ODRI do višine 4,00m [60 m2]; ŽERJAV [1%] | 46.2h |  | 465,375 |  |
| 210 | 1.1.5.21 | **Pomični odri na stolicah višine do 2,00m.** | 108.8d | 2006-04-18 A | 2006-09-05 |  | 48% | 56.76d | 2006-05-17 | 2006-08-29 | 80d | 63.6d |  |  |  |  |  |  |
| 211 | 1.1.5.21.1 | • v objektu | 80d | 2006-04-18 A | 2006-07-29 | 51 | 72% | 22.6d | 2006-05-17 | 2006-08-29 | 80d | 92.4d |  |  |  |  |  |  |
| 212 | 1.1.5.21.2 | • zunaj na balkonih | 40d | 2006-07-15 | 2006-09-05 | 70FS+10d |  |  | 2006-07-04 | 2006-08-24 | 40d | 63.6d |  |  |  |  |  |  |
| 213 | 1.1.5.22 | **Pomični odri na stolicah višine do 4,00m.** | 79d | 2006-04-18 A | 2006-07-28 |  | 73% | 21.6d | 2006-04-11 | 2006-07-21 | 79d | 93.4d |  |  |  |  | 198,000 | 144,540 |
| 214 | 1.1.5.22.1 | • v objektu | 79d | 2006-04-18 A | 2006-07-28 | 51SS | 73% | 21.6d | 2006-04-11 | 2006-07-21 | 79d | 93.4d |  |  |  |  | 198,000 | 144,540 |
| 215 | 1.1.5.23 | **Fasadni odri višine do 10m** | 74d | 2006-06-22 A | 2006-09-23 |  | 15% | 62.97d | 2006-08-01 | 2006-09-22 | 41d | 18.6d | 7.6d |  |  |  | 2,487,800 | 434,226 |
| 216 | 1.1.5.23.1 | • fasadni oder za objekt | 41d | 2006-06-22 A | 2006-09-23 | 126SS, 132, 275 | 19% | 33.4d | 2006-08-01 | 2006-09-22 | 41d | 18.6d |  |  |  |  | 2,285,400 | 434,226 |
| 217 | 1.1.5.23.2 | • fasadni oder za zunanje dvigalo | 10d | 2006-08-11 | 2006-08-25 | 126SS, 132, 275 |  |  | 2006-08-01 | 2006-08-14 | 10d | 42d | 0d |  |  |  | 202,400 |  |
| 218 | 1.1.5.24 | **Fasadni odri višine nad 10m** | 41d | 2006-08-11 | 2006-10-03 |  |  |  | 2006-08-01 | 2006-09-22 | 41d | 11d | 0d |  |  |  | 185,900 |  |
| 219 | 1.1.5.24.1 | • fasadni oder za objekt | 41d | 2006-08-11 | 2006-10-03 | 126SS, 132, 275 |  |  | 2006-08-01 | 2006-09-22 | 41d | 11d |  |  |  |  | 185,900 |  |
| 220 | 1.1.5.25 | **Fasadni odri na višini 7,00m in več** | 74d | 2006-06-22 A | 2006-09-23 |  | 19% | 60.28d | 2006-08-01 | 2006-09-22 | 41d | 18.6d | 7.6d |  |  |  | 396,500 | 75,335 |
| 221 | 1.1.5.25.1 | • fasadni oder za objekt | 41d | 2006-06-22 A | 2006-09-23 | 126SS, 132, 275 | 19% | 33.4d | 2006-08-01 | 2006-09-22 | 41d | 18.6d |  |  |  |  | 396,500 | 75,335 |
| 222 | 1.1.5.26 | **Opaž za odprtino v AB nosilcih** | 43d | 2006-05-16 A | 2006-07-11 |  | 82% | 7.7d | 2006-05-03 | 2006-06-28 | 43d | 107.3d |  |  | 8.6h | 7.06h | 120,840 | 99,088.8 |
| 223 | 1.1.5.26.1 | • velikost preboja 70/35cm | 43d | 2006-05-16 A | 2006-07-11 | 173SS+2d | 82% | 7.7d | 2006-05-03 | 2006-06-28 | 43d | 107.3d |  | OPAŽ s podporami [25 m2]; DELAVEC [2%] | 8.6h | 7.06h | 120,840 | 99,088.8 |
| 224 | 1.1.5.27 | **PVC cevi ø 200mm v AB nosilec za preboj klimo instalacije** | 4d | 2006-07-11 | 2006-07-15 |  |  |  | 2006-07-10 | 2006-07-14 | 4d | 103.4d |  |  |  |  | 254,400 |  |
| 225 | 1.1.5.27.1 | • stanovanja v 3. nadstropju | 4d | 2006-07-11 | 2006-07-15 | 176SS+2d |  |  | 2006-07-10 | 2006-07-14 | 4d | 106.6d |  | PVC KANALIZACIJSKA CEV ø 200 [12 m'] |  |  | 254,400 |  |
| 226 | 1.1.6 | **Kanalizacija** | 136.4d | 2006-03-29 A | 2006-09-20 |  | 58% | 57.22d | 2006-04-05 | 2006-09-09 | 122d | 51d |  |  | 189.3h | 60.3h | 3,193,017 | 1,563,933 |
| 227 | 1.1.6.1 | **Revizijskega jaška** | 1d | 2006-05-19 A | 2006-05-20 A |  | 100% |  | 2006-05-19 | 2006-05-20 | 1d |  |  |  | 26h | 26h | 193,000 | 193,000 |
| 228 | 1.1.6.1.1 | • B.C. ø 60cm | 1d | 2006-05-19 A | 2006-05-20 A | 236, 18 | 100% |  | 2006-05-19 | 2006-05-20 | 1d |  |  | KOMATSU [30%]; BC ø 60 cm [1 kom]; DELAVEC | 13h | 13h | 85,000 | 85,000 |
| 229 | 1.1.6.1.2 | • B.C. ø 80cm | 1d | 2006-05-19 A | 2006-05-20 A | 236, 18 | 100% |  | 2006-05-19 | 2006-05-20 | 1d |  |  | KOMATSU [30%]; BC ø 80cm [1 kom]; DELAVEC | 13h | 13h | 108,000 | 108,000 |
| 230 | 1.1.6.2 | **PVC kanalizacijske cevi** | 5d | 2006-05-17 A | 2006-05-23 A |  | 100% |  | 2006-05-19 | 2006-05-26 | 5d |  |  |  | 7.5h | 7.5h | 360,716 | 360,716 |
| 231 | 1.1.6.2.1 | • ø 150mm; pritličje | 5d | 2006-05-17 A | 2006-05-23 A | 236, 18 | 100% |  | 2006-05-19 | 2006-05-26 | 5d |  |  | PVC KANALIZACIJSKA CEV ø 150 [55 m']; KOMATSU [5%] | 2.5h | 2.5h | 238,865 | 238,865 |
| 232 | 1.1.6.2.2 | • ø 200mm; pritličje | 5d | 2006-05-17 A | 2006-05-23 A | 236, 18 | 100% |  | 2006-05-19 | 2006-05-26 | 5d |  |  | PVC KANALIZACIJSKA CEV ø 200 [16 m']; KOMATSU [5%] | 2.5h | 2.5h | 95,616 | 95,616 |
| 233 | 1.1.6.2.3 | • ø 250mm; pritličje | 5d | 2006-05-17 A | 2006-05-23 A | 236, 18 | 100% |  | 2006-05-19 | 2006-05-26 | 5d |  |  | PVC KANALIZACIJSKA CEV ø 250 [3 m']; KOMATSU [5%] | 2.5h | 2.5h | 26,235 | 26,235 |

| ID | WBS | Task | Duration | Start | Finish | Predecessors | Complete | Remaining | Baseline start | Baseline finish | Baseline duration | Total slack | Free slack | Resources | Work | Actual work | Cost | Actual cost |
| --- | --- | --- | --- | --- | --- | --- | --- | --- | --- | --- | --- | --- | --- | --- | --- | --- | --- | --- |
| 234 | 1.1.6.3 | **PVC kanalizacijske cevi s protikondenčno zaščito** | 25d | 2006-08-21 | 2006-09-20 |  |  |  | 2006-08-08 | 2006-09-09 | 25d | 51d |  |  | 50h |  | 501,888 |  |
| 235 | 1.1.6.3.1 | • ø 80mm; pod ploščo 2. nadstropja in 1. nadstropja | 25d | 2006-08-21 | 2006-09-20 | 193 |  |  | 2006-08-08 | 2006-09-09 | 25d | 54.2d | 0d | PVC ø 80 [96 m']; DELAVEC [20%] | 50h |  | 501,888 |  |
| 236 | 1.1.6.4 | Planiranje dna kanalizacijskih cevi | 1d | 2006-05-17 A | 2006-05-17 A | 40FS-7d | 100% |  | 2006-05-11 | 2006-05-19 | 6d |  |  | DELAVEC [25%] | 2.5h | 2.5h | 24,000 | 24,000 |
| 237 | 1.1.6.5 | **Drenažne cevi iz trdega PVC** | 43.8d | 2006-03-29 A | 2006-05-24 A |  | 100% |  | 2006-04-05 | 2006-05-23 | 37d |  |  |  | 21.9h | 21.9h | 890,120 | 890,120 |
| 238 | 1.1.6.5.1 | • ø 160 mm | 43.8d | 2006-03-29 A | 2006-05-24 A | 12SS+5d | 100% |  | 2006-04-05 | 2006-05-23 | 37d |  |  | DRENAŽNA CEV ø 160 [187 m']; DELAVEC [5%] | 21.9h | 21.9h | 890,120 | 890,120 |
| 239 | 1.1.6.6 | PVC cevi ø 250 v AB temelje za preboj kanalizacije | 8d | 2006-04-29 A | 2006-05-09 A | 31FS-10d | 100% |  | 2006-05-04 | 2006-05-15 | 8d |  |  | PVC cevi za preboje ø 250 [6 kom]; DELAVEC [1%] | 0.8h | 0.8h | 47,370 | 47,370 |
| 240 | 1.1.6.7 | PVC cevi ø 300 v AB temelje za preboj kanalizacije | 8d | 2006-04-29 A | 2006-05-09 A | 31FS-10d | 100% |  | 2006-05-04 | 2006-05-15 | 8d |  |  | PVC cevi za preboje ø 300 [1 kom]; DELAVEC [1%] | 0.8h | 0.8h | 11,803 | 11,803 |
| 241 | 1.1.6.8 | PVC cevi ø 150mm v AB zid za preboj kanalizacije | 8d | 2006-04-29 A | 2006-05-09 A | 31FS-10d | 100% |  | 2006-05-04 | 2006-05-15 | 8d |  |  | PVC cevi za preboje ø 150 [6 kom]; DELAVEC [1%] | 0.8h | 0.8h | 36,924 | 36,924 |
| 242 | 1.1.6.9 | **LTŽ sifona 20/20cm z izdelavo odtoka v kanalizacijo** | 60d | 2006-07-01 | 2006-09-15 |  |  |  | 2006-06-15 | 2006-09-05 | 64d | 55d |  |  | 7h |  | 142,000 |  |
| 243 | 1.1.6.9.1 | • sifoni v garaži | 3d | 2006-09-12 | 2006-09-15 | 135SS-5d, 137SS-5d |  |  | 2006-09-01 | 2006-09-05 | 3d | 58.2d |  | SIFON [9 m']; DELAVEC [20%] | 6h |  | 127,800 |  |
| 244 | 1.1.6.9.2 | • sifon pred vhodom v pritličje | 1d | 2006-07-01 | 2006-07-03 | 39SS |  |  | 2006-06-15 | 2006-06-16 | 1d | 117.2d |  | SIFON [1 m']; DELAVEC [10%] | 1h |  | 14,200 |  |
| 245 | 1.1.6.10 | **LTŽ odtočne cevi** | 20d | 2006-08-21 | 2006-09-14 |  |  |  | 2006-08-08 | 2006-09-04 | 20d | 54d |  |  | 45h |  | 228,570 |  |
| 246 | 1.1.6.10.1 | • LTŽ vertikalne odtočne cevi ø 100mm | 10d | 2006-08-21 | 2006-09-01 | 235SS |  |  | 2006-08-08 | 2006-08-22 | 10d | 67.2d | 10d | DELAVEC [30%]; LTŽ ø 100 [12 m'] | 30h |  | 169,440 |  |
| 247 | 1.1.6.10.2 | • LTŽ horizontalne odtočne cevi ø 125mm s protikondenčnim obrizgom | 10d | 2006-09-01 | 2006-09-14 | 235SS+10d |  |  | 2006-08-22 | 2006-09-04 | 10d | 57.2d | 0d | LTŽ ø 125 [3 m']; DELAVEC [15%] | 15h |  | 59,130 |  |
| 248 | 1.1.6.11 | Kanalete za odvodnjavanje na terasi 3.nadstropja | 9d | 2006-07-26 | 2006-08-07 | 140SS |  |  | 2006-07-15 | 2006-07-27 | 9d | 89.2d |  | KANALETE [61 m']; DELAVEC [30%] | 27h |  | 675,026 |  |
| 249 | 1.1.6.12 | **Preizkus vodotesnosti kanalizacijskih cevi** | 2d | 2006-09-14 | 2006-09-16 |  |  |  | 2006-09-04 | 2006-09-06 | 2d | 54d |  |  |  |  | 61,200 |  |
| 250 | 1.1.6.12.1 | ø 150mm, ø 200mm in ø 250mm | 2d | 2006-09-14 | 2006-09-16 | 231, 232, 233, 228, 229, 246, 247 |  |  | 2006-09-04 | 2006-09-06 | 2d | 57.2d |  |  |  |  | 61,200 |  |
| 251 | 1.1.6.13 | Preizkus vodotesnosti kanalizacijskih jaškov | 2d | 2006-09-14 | 2006-09-16 | 228, 229, 231, 232, 233, 246, 247 |  |  | 2006-09-04 | 2006-09-06 | 2d | 57.2d |  |  |  |  | 20,400 |  |
| 252 | 1.1.7 | **Fasaderska dela** | 65d | 2006-07-01 A | 2006-09-21 |  |  | 65d | 2006-08-01 | 2006-09-11 | 32d | 44d |  |  | 1053h |  | 14,991,135 |  |
| 253 | 1.1.7.1 | **Fasada iz izolacijskih plošč iz ekspandiranega polistirena** | 15d | 2006-07-01 A | 2006-07-20 |  |  | 15d | 2006-08-01 | 2006-08-21 | 15d | 94d |  |  | 150h |  | 7,440,210 |  |
| 254 | 1.1.7.1.1 | • deb. 8cm | 15d | 2006-07-01 A | 2006-07-20 | 215SS |  | 15d | 2006-08-01 | 2006-08-21 | 15d | 97.2d |  | POLISTIREN [1805 m2]; DELAVEC; STEKLENA MREŽICA [1805 m2]; LEPILNA MALTA [1805 m2]; ODRI do višine 4,00m [800 m2]; ODRI do višine 7,00m [500 m2]; ODRI do višine 10,00m [500 m2] | 150h |  | 7,440,210 |  |
| 255 | 1.1.7.2 | **Izdelava fasade** | 5d | 2006-08-14 | 2006-08-22 |  |  |  | 2006-08-03 | 2006-08-09 | 5d | 44d |  |  | 50h |  | 692,496 |  |
| 256 | 1.1.7.2.1 | • fasada na zunanjem zidu med shrambami in parkiriščem v 2. nadstropju | 5d | 2006-08-14 | 2006-08-22 | 215SS+2d, 218SS+2d, 220SS+2d |  |  | 2006-08-03 | 2006-08-09 | 5d | 47.2d | 0d | POLISTIREN [168 m2]; DELAVEC; STEKLENA MREŽICA [168 m2]; LEPILNA MALTA [168 m2]; ODRI do višine 4,00m [50 m2] | 50h |  | 692,496 |  |
| 257 | 1.1.7.3 | **Izdelava fasade** | 10d | 2006-08-11 | 2006-08-25 |  |  |  | 2006-08-01 | 2006-08-14 | 10d | 66d |  |  | 200h |  | 641,935 |  |
| 258 | 1.1.7.3.1 | • nad nivojem terena; deb. 8cm | 10d | 2006-08-11 | 2006-08-25 | 215SS, 218SS, 220SS |  |  | 2006-08-01 | 2006-08-14 | 10d | 69.2d |  | POLISTIREN [43 m2]; DELAVEC; STEKLENA MREŽICA [43 m2]; LEPILNA MALTA [43 m2] | 100h |  | 218,655 |  |
| 259 | 1.1.7.3.2 | • nad nivojem terena; deb. 6cm | 10d | 2006-08-11 | 2006-08-25 | 215SS, 218SS, 220SS |  |  | 2006-08-01 | 2006-08-14 | 10d | 69.2d |  | POLISTIREN [88 m2]; DELAVEC; STEKLENA MREŽICA [88 m2]; LEPILNA MALTA [88 m2] | 100h |  | 423,280 |  |

| ID | WBS | Task | Duration | Start | Finish | Predecessors | Remaining | Baseline start | Baseline finish | Baseline duration | Total slack | Free slack | Resources | Work | Cost |
| --- | --- | --- | --- | --- | --- | --- | --- | --- | --- | --- | --- | --- | --- | --- | --- |
| 260 | 1.1.7.4 | **Omet v PCM 1:2:6** | 10d | 2006-08-22 | 2006-09-02 |  |  | 2006-08-09 | 2006-08-23 | 10d | 44d |  |  | 100h | 816,720 |
| 261 | 1.1.7.4.1 | • na neizolirani fasadi | 10d | 2006-08-22 | 2006-09-02 | 256 |  | 2006-08-09 | 2006-08-23 | 10d | 47.2d | 0d | DELAVEC; OMET V PCM 1:2:6 [498 m2]; ODRI do višine 4,00m [200 m2]; ODRI do višine 7,00m [150 m2]; ODRI do višine 10,00m [150 m2] | 100h | 816,720 |
| 262 | 1.1.7.5 | **Zaključni sloj fasade** | 25d | 2006-08-22 | 2006-09-21 |  |  | 2006-08-09 | 2006-09-11 | 25d | 44d |  |  | 420h | 4,560,930 |
| 263 | 1.1.7.5.1 | • na izolirani in neizolirani fasadi | 15d | 2006-09-04 | 2006-09-21 | 261 |  | 2006-08-23 | 2006-09-11 | 15d | 47.2d |  | DELAVEC [200%]; SILIKATNI OMET [2195 m2]; ODRI do višine 4,00m [800 m2]; ODRI do višine 7,00m [600 m2]; ODRI do višine 10,00m [600 m2] | 300h | 4,104,650 |
| 264 | 1.1.7.5.2 | • fasada na zunanjem zidu med shrambami in parkiriščem v 2. nadstropju | 10d | 2006-08-22 | 2006-09-02 | 256 |  | 2006-08-09 | 2006-08-23 | 10d | 62.2d |  | DELAVEC; SILIKATNI OMET [168 m2]; ODRI do višine 4,00m [50 m2] | 100h | 314,160 |
| 265 | 1.1.7.5.3 | • zunanje dvigalo | 4d | 2006-08-25 | 2006-08-30 | 271, 217 |  | 2006-08-14 | 2006-08-19 | 4d | 65.2d |  | SILIKATNI OMET [76 m2]; DELAVEC [50%]; ODRI do višine 4,00m [30 m2]; ODRI do višine 7,00m [20 m2]; ODRI do višine 10,00m [25 m2] | 20h | 142,120 |
| 266 | 1.1.7.6 | **Zaključni sloj fasade** | 45d | 2006-07-01 A | 2006-08-28 |  | 45d | 2006-08-01 | 2006-08-17 | 12d | 64d |  |  | 55h | 684,684 |
| 267 | 1.1.7.6.1 | • podstavek fasade | 9d | 2006-07-01 A | 2006-07-12 | 215SS | 9d | 2006-08-01 | 2006-08-11 | 9d | 103.2d |  | DELAVEC [50%]; ZAKLJUČNI SLOJ FASADE [239 m2] | 45h | 635,740 |
| 268 | 1.1.7.6.2 | • podstavek fasade; zunanje dvigalo | 2d | 2006-08-25 | 2006-08-28 | 272, 217 |  | 2006-08-14 | 2006-08-17 | 2d | 67.2d |  | DELAVEC [25%]; ZAKLJUČNI SLOJ FASADE [3.4 m2] | 5h | 9,044 |
| 269 | 1.1.7.6.3 | • zunanje stene stopnišča | 2d | 2006-08-18 | 2006-08-22 | 272 |  | 2006-08-07 | 2006-08-09 | 2d | 72.2d |  | DELAVEC [25%]; ZAKLJUČNI SLOJ FASADE [15 m2] | 5h | 39,900 |
| 270 | 1.1.7.7 | **Omet zunanjih sten v PCM 1:2:6** | 6d | 2006-08-14 | 2006-08-23 |  |  | 2006-08-03 | 2006-08-10 | 6d | 64d |  |  | 78h | 154,160 |
| 271 | 1.1.7.7.1 | • stene zunanjega dvigala | 6d | 2006-08-14 | 2006-08-23 | 215SS+2d, 218SS+2d, 220SS+2d |  | 2006-08-03 | 2006-08-10 | 6d | 67.2d | 2d | OMET V PCM 1:2:6 [79 m2]; DELAVEC; ODRI do višine 4,00m [30 m2]; ODRI do višine 7,00m [30 m2]; ODRI do višine 10,00m [30 m2] | 60h | 129,560 |
| 272 | 1.1.7.7.2 | • zunanje stene stopnišča | 3d | 2006-08-14 | 2006-08-18 | 215SS+2d, 218SS+2d, 220SS+2d |  | 2006-08-03 | 2006-08-07 | 3d | 72.2d | 0d | OMET V PCM 1:2:6 [15 m2]; DELAVEC [60%]; ODRI do višine 4,00m [15 m2] | 18h | 24,600 |
| 273 | 1.2 | **Obrtniška dela** | 106.4d | 2006-07-05 | 2006-11-17 |  |  | 2006-07-15 | 2006-11-08 | 89d | 0d |  |  |  | 225,457,262 |
| 274 | 1.2.1 | **Krovska dela** | 4d | 2006-07-05 | 2006-07-10 |  |  | 2006-07-17 | 2006-07-21 | 4d | 37.4d |  |  |  | 56,798,994 |
| 275 | 1.2.1.1 | Montaža strehe | 4d | 2006-07-05 | 2006-07-10 | 179FS+2d |  | 2006-07-17 | 2006-07-21 | 4d | 37.4d | 0d |  |  | 47,618,064 |
| 276 | 1.2.2 | Kleparska dela | 10d | 2006-07-10 | 2006-07-21 | 275 |  | 2006-07-21 | 2006-08-03 | 10d | 92.4d |  |  |  | 2,248,995 |
| 277 | 1.2.3 | Ključavničarska dela | 21d | 2006-08-09 | 2006-09-05 | 39, 64, 66, 67, 106 |  | 2006-07-29 | 2006-08-25 | 21d | 57d |  |  |  | 27,711,466.5 |
| 278 | 1.2.4 | Mizarska dela | 33d | 2006-09-19 | 2006-11-02 | 80FS+5d, 81FS+5d, 83FS+5d |  | 2006-09-08 | 2006-10-19 | 33d | 13d |  |  |  | 15,167,194.5 |
| 279 | 1.2.5 | PVC in ALU dela | 21d | 2006-09-19 | 2006-10-16 | 80FS+5d, 81FS+5d, 83FS+5d |  | 2006-09-08 | 2006-10-05 | 21d | 23d | 0d |  |  | 33,561,029.5 |
| 280 | 1.2.6 | **Montažni stropovi in zidovi** | 75d | 2006-07-26 | 2006-10-30 |  |  | 2006-07-15 | 2006-10-18 | 75d | 14d |  |  |  | 34,483,539 |
| 281 | 1.2.6.1 | Stropovi | 39d | 2006-09-11 | 2006-10-30 | 105, 107, 109FS-8d |  | 2006-08-31 | 2006-10-18 | 39d | 14d |  |  |  |  |
| 282 | 1.2.6.2 | Predelne stene | 45d | 2006-07-26 | 2006-09-21 | 113SS |  | 2006-07-15 | 2006-09-11 | 45d | 44d |  |  |  |  |
| 283 | 1.2.7 | Tlakarska dela | 30d | 2006-10-10 | 2006-11-17 | 133SS+5d |  | 2006-09-28 | 2006-11-08 | 30d | 0d |  |  |  | 11,746,658 |

| ID | WBS | Task | Type | Duration | Start | Finish | Predecessors | Complete | Remaining | Baseline start | Baseline finish | Baseline duration | Total slack | Free slack | Constraint | Resources | Work | Actual work | Cost | Actual cost |
| --- | --- | --- | --- | --- | --- | --- | --- | --- | --- | --- | --- | --- | --- | --- | --- | --- | --- | --- | --- | --- |
| 284 | 1.2.8 | **Kamnoseška dela** |  | 75.4d | 2006-07-14 | 2006-10-18 |  |  |  | 2006-07-27 | 2006-10-07 | 57d | 23d |  |  |  |  |  | 2,192,599.5 |  |
| 285 | 1.2.8.1 | Okenske police |  | 18d | 2006-09-26 | 2006-10-18 | 279SS+5d |  |  | 2006-09-14 | 2006-10-07 | 18d | 23d |  |  |  |  |  |  |  |
| 286 | 1.2.8.2 | Polaganje naravnega kamna |  | 24d | 2006-07-14 | 2006-08-14 | 67FS+5d, 164FS+5d |  |  | 2006-07-27 | 2006-08-28 | 24d | 74.4d |  |  |  |  |  |  |  |
| 287 | 1.2.9 | Keramičarska dela |  | 33d | 2006-09-25 | 2006-11-07 | 122FS+5d |  |  | 2006-09-13 | 2006-10-25 | 33d | 9d |  |  |  |  |  | 31,255,990 |  |
| 288 | 1.2.10 | Slikopleskarska dela |  | 80d | 2006-07-07 | 2006-10-17 | 60FS+5d |  |  | 2006-07-25 | 2006-11-06 | 80d | 24d | 0d |  |  |  |  | 10,290,796 |  |
| 289 | 1.3 | **Inštalacije** |  | 129d | 2006-05-26 A | 2006-11-09 |  | 18% | 106.09d | 2006-05-15 | 2006-10-27 | 130d | 7d |  |  |  | 1690h | 135h | 117,943,725.64 | 21,229,870.62 |
| 290 | 1.3.1 | Groba montaža |  | 90d | 2006-05-26 A | 2006-09-19 | 69SS-1d | 30% | 63d | 2006-05-15 | 2006-09-07 | 90d | 46d |  |  | DELAVEC [50%]; ELEKTRO MATERIAL | 450h | 135h |  |  |
| 291 | 1.3.2 | Fina montaža |  | 62d | 2006-08-22 | 2006-11-09 | 122SS+15d |  |  | 2006-08-09 | 2006-10-27 | 62d | 5d | 0d |  | DELAVEC [200%]; ELEKTRO MATERIAL | 1240h |  |  |  |
| 292 | 1.4 | **Oprema** |  | 69.4d | 2006-08-14 | 2006-11-11 |  |  |  | 2006-07-27 | 2006-11-03 | 77d | 5d |  |  |  |  |  | 12,075,313 |  |
| 293 | 1.4.1 | Požarna oprema |  | 4d | 2006-10-11 | 2006-10-16 | 288FS-5d |  |  | 2006-10-27 | 2006-11-03 | 4d | 28.2d |  |  |  |  |  | 330,834 |  |
| 294 | 1.4.2 | Dvigala |  | 18d | 2006-08-14 | 2006-09-06 | 73FS+27d, 74FS+27d |  |  | 2006-07-27 | 2006-08-19 | 18d | 59.6d |  |  |  |  |  | 9,570,750 |  |
| 295 | 1.4.3 | Zgibna zapornica |  | 2d | 2006-11-09 | 2006-11-11 | 291 |  |  | 2006-10-27 | 2006-10-30 | 2d | 8.2d |  |  |  |  |  | 902,760 |  |
| 296 | 1.4.4 | Ostala oprema |  | 24d | 2006-10-03 | 2006-11-04 | 215, 218, 220 |  |  | 2006-09-22 | 2006-10-23 | 24d | 14.2d |  |  |  |  |  | 1,270,969 |  |
| 297 | 1.5 | Zunanja ureditev |  | 74d | 2006-07-01 A | 2006-10-03 | 19, 20 |  | 74d | 2006-06-12 | 2006-09-13 | 74d | 38.2d | 35d |  | DELAVEC [20%]; KOMATSU [2%] | 162.8h |  | 12,891,149.37 |  |
| 298 | 1.6 | Kontrolna točka | milestone | 1d | 2006-06-30 A | 2006-06-30 A |  | 100% |  |  |  |  |  |  | start no earlier than 2006-06-30 |  |  |  |  |  |
